# Proyecto CRM - Corporacion Union

Schedule from MS Project, 2005-11-29 to 2006-03-31.

## Calendars

- Estándar: Mon-Fri 08:00-12:00, 13:00-17:00; Sat-Sun off. Exceptions (off unless hours are given): 2006-02-27 to 2006-02-28.

## Resources

| Resource |
| --- |
| Olga |
| R1 |
| Listbeth |
| R2 |
| Eilyn |
| Corp. Unión |
| Maribel |
| Kernel GWT |
| Aron |

## Schedule

| ID | WBS | Task | Type | Duration | Start | Finish | Predecessors | Total slack | Free slack | Constraint | Resources | Work |
| --- | --- | --- | --- | --- | --- | --- | --- | --- | --- | --- | --- | --- |
| 1 | 1 | **Proyecto Rediseño Conexión Union** |  | 87d | 2005-11-29 | 2006-03-31 |  | 0d |  |  |  | 4100h |
| 2 | 1.1 | **Inicio** |  | 4d | 2005-11-29 | 2005-12-02 |  | 83d |  |  |  | 56h |
| 3 | 1.1.1 | Reunión de Arranque (Kickoff) |  | 1d | 2005-11-29 | 2005-11-29 |  | 86d |  |  | Olga; Listbeth; Corp. Unión | 24h |
| 4 | 1.1.2 | Reunión con nuevos integrantes del equipo |  | 1d | 2005-12-02 | 2005-12-02 |  | 83d |  | start no earlier than 2005-12-02 | Olga; Listbeth; Maribel; Corp. Unión | 32h |
| 5 | 1.2 | **Especificación de Requerimientos** |  | 39d | 2005-12-08 | 2006-01-31 |  | 41d |  |  |  | 708h |
| 6 | 1.2.1 | **Levantamiento de Información** |  | 22d | 2005-12-08 | 2006-01-06 |  | 47d |  |  |  | 544h |
| 7 | 1.2.1.1 | Sesión de Trabajo # 1 para revisar / definir requerimientos |  | 1d | 2005-12-08 | 2005-12-08 |  | 79d |  | start no earlier than 2005-12-08 | Olga; Listbeth; Corp. Unión; Maribel | 32h |
| 8 | 1.2.1.2 | Sesión de Trabajo # 2 para detalles de requerimientos |  | 1d | 2005-12-16 | 2005-12-16 |  | 41d | 0d | start no earlier than 2005-12-16 | Olga; Listbeth; Corp. Unión; Maribel | 32h |
| 9 | 1.2.1.3 | Continuar Levantamiento de Requerimientos, detalles y ajustes |  | 15d | 2005-12-19 | 2006-01-06 | 8 | 41d | 0d |  | Olga; Listbeth; Corp. Unión; Maribel | 480h |
| 10 | 1.2.2 | Elaboración del Informe Esp. de Req. y Matriz de Req. |  | 4d | 2006-01-09 | 2006-01-12 | 9 | 41d | 0d | start no earlier than 2005-12-12 | Maribel; Listbeth [50%] | 48h |
| 11 | 1.2.3 | Entrega al Equipo de Proyecto para su revisión | milestone | 0d | 2006-01-12 | 2006-01-12 | 10 | 41d | 0d |  | Maribel |  |
| 12 | 1.2.4 | Revisión por parte del Equipo de Proyecto |  | 5d | 2006-01-13 | 2006-01-19 | 11 | 41d | 0d |  | Corp. Unión | 40h |
| 13 | 1.2.5 | Ajustes al Informe Especificación de Requerimientos |  | 3d | 2006-01-20 | 2006-01-24 | 12 | 41d | 0d |  | Maribel; Listbeth [50%] | 36h |
| 14 | 1.2.6 | Entrega de Especificación de Requerimientos para aprobación | milestone | 0d | 2006-01-24 | 2006-01-24 | 13 | 41d | 0d |  | Listbeth |  |
| 15 | 1.2.7 | Revisión por parte de Corporación Unión |  | 5d | 2006-01-25 | 2006-01-31 | 14 | 41d | 0d |  | Corp. Unión | 40h |
| 16 | 1.2.8 | Aprobación del Informe Especificación de Requerimientos | milestone | 0d | 2006-01-31 | 2006-01-31 | 15, 14 | 41d | 0d | start no earlier than 2005-06-03 | Corp. Unión |  |
| 17 | 1.3 | Informe Especificación de Requerimientos Aprobado | milestone | 0d | 2006-01-31 | 2006-01-31 | 16 | 41d |  | start no earlier than 2005-05-23 |  |  |
| 18 | 1.4 | **Configuración y Desarrollo** |  | 50d | 2006-01-02 | 2006-03-14 |  | 1d | 0d |  |  | 1904h |
| 19 | 1.4.1 | Ajustes WIB para Conexión Union y aplicaciones relacionadas |  | 42d | 2006-01-02 | 2006-02-28 |  | 1d | 0d | start no earlier than 2006-01-02 | Kernel GWT | 336h |
| 20 | 1.4.2 | **Desarrollo de Nuevas Funcionalidades** |  | 43d | 2006-01-10 | 2006-03-13 |  | 2d |  |  |  | 1408h |
| 21 | 1.4.2.1 | Avisos Clasificados |  | 15d | 2006-01-10 | 2006-01-30 |  | 30d |  | start no earlier than 2006-01-10 | Eilyn; Listbeth | 240h |
| 22 | 1.4.2.2 | Administración y Consulta Sedes y Servicios |  | 10d | 2006-01-31 | 2006-02-13 |  | 20d |  | start no earlier than 2006-01-31 | Eilyn; Maribel | 160h |
| 23 | 1.4.2.3 | Envío personalizado email masivos a Relacionados |  | 10d | 2006-02-02 | 2006-02-15 |  | 18d |  | start no earlier than 2006-02-02 | Olga; R1 | 160h |
| 24 | 1.4.2.4 | Cambios aplicación Contáctanos |  | 15d | 2006-02-13 | 2006-03-07 |  | 6d |  | start no earlier than 2006-02-13 | Olga; Eilyn | 240h |
| 25 | 1.4.2.5 | Administración de Banners y Caricaturas |  | 8d | 2006-02-10 | 2006-02-21 |  | 14d |  | start no earlier than 2006-02-10 | Listbeth; R2 | 128h |
| 26 | 1.4.2.6 | Administración de Anuncios Corporativos |  | 4d | 2006-02-15 | 2006-02-20 |  | 15d |  | start no earlier than 2006-02-15 | Maribel; R1 | 64h |
| 27 | 1.4.2.7 | Control y Seguimiento ingreso y actualización DT |  | 8d | 2006-03-02 | 2006-03-13 |  | 2d |  | start no earlier than 2006-03-02 | Listbeth; Eilyn; Maribel | 192h |
| 28 | 1.4.2.8 | Autorización Documentos Prevención |  | 8d | 2006-02-16 | 2006-03-01 |  | 10d |  | start no earlier than 2006-02-16 | Listbeth | 64h |
| 29 | 1.4.2.9 | Administración Ventanas Emergentes (Broadcast) |  | 10d | 2006-02-21 | 2006-03-08 |  | 5d |  | start no earlier than 2006-02-21 | Maribel; R1 | 160h |
| 30 | 1.4.3 | Incorporar diseño definido del Site en WIB |  | 10d | 2006-03-01 | 2006-03-14 | 19 | 1d | 0d |  | Listbeth; Kernel GWT | 160h |
| 31 | 1.5 | Nuevo diseño de la intranet configurado | milestone | 0d | 2006-03-14 | 2006-03-14 | 30 | 13d |  |  |  |  |
| 32 | 1.6 | Nuevas funcionalidades en la Intranet incorporadas | milestone | 0d | 2006-03-14 | 2006-03-14 | 30 | 13d |  |  |  |  |

Notes:
- 20: Esta tarea incluye: desarrollo, pruebas internas, pruebas externas y documentación

| ID | WBS | Task | Type | Duration | Start | Finish | Predecessors | Total slack | Free slack | Constraint | Resources | Work |
| --- | --- | --- | --- | --- | --- | --- | --- | --- | --- | --- | --- | --- |
| 33 | 1.7 | **Plan de Pruebas** |  | 5d | 2006-02-15 | 2006-02-21 |  | 26d |  |  |  | 56h |
| 34 | 1.7.1 | Elaboración Plan de Pruebas |  | 3d | 2006-02-15 | 2006-02-17 |  | 26d | 0d | start no earlier than 2006-02-15 | Maribel; Listbeth [50%] | 36h |
| 35 | 1.7.2 | Revisión Plan de Pruebas con Equipo de Trabajo |  | 1d | 2006-02-20 | 2006-02-20 | 34 | 26d | 0d |  | Corp. Unión | 8h |
| 36 | 1.7.3 | Ajustes recomendados al Plan de Pruebas |  | 1d | 2006-02-21 | 2006-02-21 | 35 | 26d | 0d |  | Listbeth [50%]; Maribel | 12h |
| 37 | 1.8 | Plan de Pruebas elaborado y revisado | milestone | 0d | 2006-02-21 | 2006-02-21 | 36 | 26d |  |  |  |  |
| 38 | 1.9 | **Pruebas de Certificación** |  | 8d | 2006-03-15 | 2006-03-24 |  | 1d |  |  |  | 152h |
| 39 | 1.9.1 | Preparación para las pruebas en ambiente de desarrollo |  | 1d | 2006-03-15 | 2006-03-15 | 18, 32 | 1d | 0d | start no earlier than 2005-06-20 | Aron | 8h |
| 40 | 1.9.2 | Realización de Pruebas de Funcionalidad |  | 5d | 2006-03-16 | 2006-03-22 | 39 | 1d | 0d | start no earlier than 2005-07-12 | Olga; Corp. Unión | 80h |
| 41 | 1.9.3 | Realización de Ajustes recomendados |  | 2d | 2006-03-23 | 2006-03-24 | 40 | 1d | 0d |  | Olga; Listbeth; Eilyn; Maribel | 64h |
| 42 | 1.9.4 | Pruebas de Certificación aprobada | milestone | 0d | 2006-03-24 | 2006-03-24 | 41 | 1d | 0d |  |  |  |
| 43 | 1.10 | **Documentación** |  | 50d | 2006-01-09 | 2006-03-21 |  | 8d |  |  |  | 720h |
| 44 | 1.10.1 | **Procesos** |  | 30d | 2006-01-09 | 2006-02-17 |  | 28d |  |  |  | 240h |
| 45 | 1.10.1.1 | Directorio de Trabajadores |  | 15d | 2006-01-09 | 2006-01-27 |  | 28d | 0d | start no earlier than 2006-01-09 | Corp. Unión | 120h |
| 46 | 1.10.1.2 | Directorio de Sedes y Servicios |  | 15d | 2006-01-30 | 2006-02-17 | 45 | 28d |  |  | Corp. Unión | 120h |
| 47 | 1.10.2 | Técnica WIB y Aplicaciones |  | 15d | 2006-03-01 | 2006-03-21 | 32 | 8d |  | start no earlier than 2006-03-01 | Olga; Listbeth; Eilyn; Maribel | 480h |
| 48 | 1.11 | **Preparación para el aranque** |  | 20d | 2006-03-01 | 2006-03-28 |  | 3d |  |  |  | 40h |
| 49 | 1.11.1 | **Desarrollo** |  | 3d | 2006-03-01 | 2006-03-03 |  | 20d |  |  |  | 24h |
| 50 | 1.11.1.1 | Configuración Infraestructura Técnica |  | 3d | 2006-03-01 | 2006-03-03 | 19 | 20d |  |  | Aron | 24h |
| 51 | 1.11.2 | **Producción** |  | 2d | 2006-03-27 | 2006-03-28 |  | 1d | 0d |  |  | 16h |
| 52 | 1.11.2.1 | Configuración Infraestructura Técnica |  | 2d | 2006-03-27 | 2006-03-28 | 42, 30 | 1d |  |  | Aron | 16h |
| 53 | 1.12 | Puesta en Producción |  | 2d | 2006-03-29 | 2006-03-30 | 51 | 1d |  |  | Listbeth; Corp. Unión | 32h |
| 54 | 1.13 | Adiestramiento |  | 7d | 2006-03-20 | 2006-03-28 |  | 3d |  | start no earlier than 2006-03-20 | Olga; Listbeth; Maribel | 168h |
| 55 | 1.14 | Manejo del Cambio |  | 10d | 2006-03-15 | 2006-03-28 |  | 3d |  | start no earlier than 2006-03-15 | Corp. Unión | 80h |
| 56 | 1.15 | **Gerencia de Proyecto** |  | 20d | 2005-12-14 | 2006-01-10 |  | 56d |  |  |  | 160h |
| 57 | 1.15.1 | Planificación |  | 20d | 2005-12-14 | 2006-01-10 |  | 56d |  | start no earlier than 2005-12-14 | Listbeth | 160h |

Notes:
- 54: Incluye: / - Administración WIB / - Envío de emails masivos / - Adm. de Banners y Caricaturas / - Adm. de Avisos Corporativos y Ventanas Emergentes / - Adm. Sedes y Servicios / - Buzón Contáctanos / - Adm. Avisos Clasificados

| ID | WBS | Task | Duration | Start | Finish | Predecessors | Total slack | Constraint | Resources | Work |
| --- | --- | --- | --- | --- | --- | --- | --- | --- | --- | --- |
| 58 | 1.16 | **Cierre** | 5d | 2006-03-27 | 2006-03-31 |  | 0d |  |  | 24h |
| 59 | 1.16.1 | Preparación Presentación Cierre de Proyecto | 2d | 2006-03-27 | 2006-03-28 | 53 | 3d | start no earlier than 2006-03-27 | Listbeth | 16h |
| 60 | 1.16.2 | Reunión Cierre de Proyecto | 1d | 2006-03-31 | 2006-03-31 | 59 | 0d | start no earlier than 2006-03-31 | Listbeth | 8h |
