# Proyecto CRM - Corporacion Union

Schedule from MS Project, 2005-11-29 to 2006-02-02.

## Calendars

- Estándar: Mon-Fri 08:00-12:00, 13:00-17:00; Sat-Sun off.

## Resources

| Resource |
| --- |
| Olga |
| R1 |
| Listbeth |
| R2 |
| Eilyn |
| Corp. Unión |
| Maribel |
| Kernel GWT |
| Aron |

## Schedule

| ID | WBS | Task | Type | Duration | Start | Finish | Predecessors | Total slack | Free slack |
| --- | --- | --- | --- | --- | --- | --- | --- | --- | --- |
| 1 | 1 | **Nombre del Proyecto** |  | 48d | 2005-11-29 | 2006-02-02 |  | 0d |  |
| 2 | 1.1 | **Inicio** |  | 1d | 2005-11-29 | 2005-11-29 |  | 37d |  |
| 3 | 1.1.1 | Reunión de Arranque (Kickoff) |  | 1d | 2005-11-29 | 2005-11-29 |  | 15d |  |
| 4 | 1.2 | **Especificación de Requerimientos** |  | 11d | 2005-11-29 | 2005-12-13 |  | 27d |  |
| 5 | 1.2.1 | **Levantamiento de Información** |  | 1d | 2005-11-29 | 2005-11-29 |  | 37d |  |
| 6 | 1.2.1.1 | Sesión de Trabajo # 1 |  | 1d | 2005-11-29 | 2005-11-29 |  | 15d |  |
| 7 | 1.2.1.2 | Sesión de Trabajo # 2 |  | 1d | 2005-11-29 | 2005-11-29 |  | 15d |  |
| 8 | 1.2.2 | Elaboración del Informe Esp. de Req. y Matriz de Req. |  | 5d | 2005-11-29 | 2005-12-05 |  | 3d | 0d |
| 9 | 1.2.3 | Entrega al Equipo de Proyecto para su revisión | milestone | 0d | 2005-12-05 | 2005-12-05 | 8 | 3d | 0d |
| 10 | 1.2.4 | Revisión por parte del Equipo de Proyecto |  | 2d | 2005-12-06 | 2005-12-07 | 9 | 3d | 0d |
| 11 | 1.2.5 | Ajustes al Informe Especificación de Requerimientos |  | 1d | 2005-12-08 | 2005-12-08 | 10 | 3d | 0d |
| 12 | 1.2.6 | Entrega de Especificación de Requerimientos para aprobación | milestone | 0d | 2005-12-08 | 2005-12-08 | 11 | 3d | 0d |
| 13 | 1.2.7 | Revisión por parte del Cliente |  | 3d | 2005-12-09 | 2005-12-13 | 12 | 3d | 0d |
| 14 | 1.2.8 | Aprobación del Informe Especificación de Requerimientos | milestone | 0d | 2005-12-13 | 2005-12-13 | 13, 12 | 27d | 0d |
| 15 | 1.3 | Informe Especificación de Requerimientos Aprobado | milestone | 0d | 2005-12-13 | 2005-12-13 | 14 | 27d |  |
| 16 | 1.4 | **Configuración y Desarrollo** |  | 10d | 2005-11-29 | 2005-12-12 |  | 0d |  |
| 17 | 1.4.1 | Act x |  | 10d | 2005-11-29 | 2005-12-12 |  | 0d |  |
| 18 | 1.4.2 | **Desarrollo de Nuevas Funcionalidades** |  | 10d | 2005-11-29 | 2005-12-12 |  | 0d |  |
| 19 | 1.4.2.1 | x |  | 10d | 2005-11-29 | 2005-12-12 |  | 0d |  |
| 20 | 1.4.2.2 | y |  | 10d | 2005-11-29 | 2005-12-12 |  | 0d |  |
| 21 | 1.4.2.3 | z |  | 8d | 2005-11-29 | 2005-12-08 |  | 2d |  |
| 22 | 1.4.3 | Ejecución de pruebas internas |  | 5d | 2005-11-29 | 2005-12-05 |  | 5d |  |
| 23 | 1.5 | Nuevas funcionalidades | milestone | 0d | 2005-11-29 | 2005-11-29 |  | 16d |  |
| 24 | 1.6 | **Plan de Pruebas** |  | 5d | 2005-11-29 | 2005-12-05 |  | 33d |  |
| 25 | 1.6.1 | Elaboración Plan de Pruebas |  | 3d | 2005-11-29 | 2005-12-01 |  | 33d | 0d |
| 26 | 1.6.2 | Revisión Plan de Pruebas con Equipo de Trabajo |  | 1d | 2005-12-02 | 2005-12-02 | 25 | 33d | 0d |
| 27 | 1.6.3 | Ajustes recomendados al Plan de Pruebas |  | 1d | 2005-12-05 | 2005-12-05 | 26 | 33d | 0d |
| 28 | 1.7 | Plan de Pruebas elaborado y revisado | milestone | 0d | 2005-12-05 | 2005-12-05 | 27 | 33d |  |

Notes:
- 1: 1) Esta plantilla pretende apoyar al Gerente de proyecto en la elaboración de cronogramas de proyectos para el desarrollo y configuración de soluciones. Especifica las actividades y los productos obtenidos en cada actividad o grupo de ellas. / 2) La planificación se está realizando por días laborables. Si en una actividad no se requiere esfuerzo de días completos (8 horas) para una actividad, entonces se especifica el porcentaje (%) de dedicación a la actividad. Por ejemplo, si se tiene una tarea con duración de 1 día, pero el recurso le va a dedicar solo4 horas, en la asignación del recurso se colocaría 50%.
- 3: Esta tarea representa la reunión con el cliente o equipo de proyecto, para la formalización del iincio del proyecto (en aquellos casos que aplique). Aquí no se contempla el tiempo que dedica el Gerente del Proyecto a la preparación de la presentación para esta reunión, debido a que las actividades en este plan se reflejan a partir de este arranque.
- 5: Se estima un día por sesión de levantamiento de requerimientos. Existen proyectos donde el lev. de información se hace con ejecución de talleres con duración estimada de 2 días hasta una semana. Todo depende. Lo importante es reflejar cada sesión, duración y las fechas pautadas para su ejecución.
- 16: Los tiempos a incorporar en las tareas que se presentan a continuación dependerán de la complejidad del proyecto a nivel de aplicaciones, configuración de herramientas del kernel, Site, etc.
- 18: En caso de que el proyecto contemple varias aplicaciones, se recomienda dimensionar cada una por separado, además de especificar precedencia en caso de que exista

| ID | WBS | Task | Type | Duration | Start | Finish | Predecessors | Total slack |
| --- | --- | --- | --- | --- | --- | --- | --- | --- |
| 29 | 1.8 | **Pruebas de Certificación** |  | 15d | 2005-12-13 | 2006-01-02 |  | 0d |
| 30 | 1.8.1 | Preparación para las pruebas en ambiente de desarrollo |  | 3d | 2005-12-13 | 2005-12-15 | 16, 23 | 0d |
| 31 | 1.8.2 | Realización de Pruebas de Funcionalidad |  | 7d | 2005-12-16 | 2005-12-26 | 30 | 0d |
| 32 | 1.8.3 | Realización de Ajustes recomendados |  | 5d | 2005-12-27 | 2006-01-02 | 31 | 0d |
| 33 | 1.8.4 | Pruebas de Certificación aprobada | milestone | 0d | 2006-01-02 | 2006-01-02 | 32 | 0d |
| 34 | 1.9 | Documentación |  | 15d | 2005-11-29 | 2005-12-19 |  | 23d |
| 35 | 1.10 | **Preparación para el aranque** |  | 18d | 2005-12-13 | 2006-01-05 |  | 10d |
| 36 | 1.10.1 | **Desarrollo** |  | 3d | 2005-12-13 | 2005-12-15 |  | 25d |
| 37 | 1.10.1.1 | Configuración Infraestructura Técnica |  | 3d | 2005-12-13 | 2005-12-15 | 17 | 25d |
| 38 | 1.10.2 | **Producción** |  | 3d | 2006-01-03 | 2006-01-05 |  | 0d |
| 39 | 1.10.2.1 | Configuración Infraestructura Técnica |  | 3d | 2006-01-03 | 2006-01-05 | 33 | 0d |
| 40 | 1.11 | **Puesta en Producción** |  | 20d | 2006-01-06 | 2006-02-02 | 38 | 0d |
| 41 | 1.11.1 | Adiestramiento |  | 10d | 2006-01-06 | 2006-01-19 |  | 10d |
| 42 | 1.11.2 | Manejo del Cambio |  | 20d | 2006-01-06 | 2006-02-02 |  | 0d |
| 43 | 1.11.3 | **Gerencia de Proyecto** |  | 10d | 2006-01-06 | 2006-01-19 |  | 10d |
| 44 | 1.11.3.1 | Planificación |  | 10d | 2006-01-06 | 2006-01-19 |  | 10d |
| 45 | 1.11.4 | **Cierre** |  | 2d | 2006-01-06 | 2006-01-09 |  | 18d |
| 46 | 1.11.4.1 | Preparación Presentación Cierre de Proyecto |  | 2d | 2006-01-06 | 2006-01-09 | 40 | 18d |
| 47 | 1.11.4.2 | Reunión Cierre de Proyecto |  | 1d | 2006-01-06 | 2006-01-06 | 46 | 19d |

Notes:
- 31: La duración de esta actividad depende de la cantidad y complejidad de las aplicaciones o funcionalidades configuradas como parte de los productos a entregar en el proyecto.
- 34: Esta actividad incluye la elaboración de la Guía de Usuarios, Guía Técnica y cualquier documento necesario o comprometido como parte de los productos a entregar en el proyecto. También su duración dependerá de la cantidad de aplicaciones y/o funcionalidades desarrolladas en el proyecto.
- 37: La estimación de la duración de esta actividad la debemos realizar con el equipo de Operaciones, asi como la fecha de inicio
- 39: La estimación de la duración de esta actividad la debemos realizar junto con el equipo de Operaciones, asi como la fecha de inicio
- 41: Contempla todas las tareas relacionadas con el adiestramiento, desde la preparación del material de apoyo para su ejecución, como las sesiones que se realicen para la inducción del usuario
- 42: Corresponde a todas las actividades que se realizarán en el proyecto en esta área. En algunas ocasiones lo hacemos nosotros (GWT), en otras es responsabilidad del cliente. Independientemente de ello, se considera importante reflejar su duración y fecha de inicio. A pesar que lo haga el cliente, siempre existirán horas de apoyo nuestro
- 43: Horas que dedica el Gerente de proyecto en la preparación, planificación
