# Plan Implantacion Genesismpp

Schedule from MS Project, 2006-03-22 to 2006-08-17, A marks actual dates.
gm

## Calendars

- Estándar: Mon-Fri 09:00-13:00, 15:00-19:00; Sat-Sun off. Exceptions (off unless hours are given): 2006-04-13 to 2006-04-14, 2006-04-19, 2006-05-01.

## Resources

| Resource |
| --- |
| Rec. Comercial |
| Req. Operaciones |
| Rec. Manten |
| Rea. Admin |
| Usuario |
| Req. Operaciones 2 |
| Req. Operaciones2 |
| R4 |
| R5 |
| E. Araujo |
| E.Araujo |
| R1 |
| R2 |

## Schedule

| ID | WBS | Task | Type | Duration | Start | Finish | Predecessors | Complete | Remaining | Total slack | Free slack | Constraint | Resources | Work | Actual work |
| --- | --- | --- | --- | --- | --- | --- | --- | --- | --- | --- | --- | --- | --- | --- | --- |
| 1 | 1 | **Plan Implatación Génesis** |  | 103d? | 2006-03-22 A | 2006-08-17 |  | 34% | 67.93d? | 0d |  |  |  | 1029.33h | 379.07h |
| 2 | 1.1 | **Pruebas Funcionales** |  | 32d? | 2006-03-22 A | 2006-05-10 |  | 87% | 4.18d? | 71d |  |  |  | 381.33h | 324.67h |
| 3 | 1.1.1 | Acceso |  | 2d | 2006-03-22 A | 2006-03-23 A |  | 100% |  |  |  | start no earlier than 2006-03-22 | Usuario | 16h | 16h |
| 4 | 1.1.2 | **Comercial** |  | 22d? | 2006-03-22 A | 2006-04-26 |  | 91% | 1.96d? | 81d |  |  |  | 56h | 47.6h |
| 5 | 1.1.2.1 | Grupo/Subgrupos/Servicios |  | 1d | 2006-03-22 A | 2006-03-22 A |  | 100% |  |  |  | start no earlier than 2006-03-22 | Rec. Comercial | 8h | 8h |
| 6 | 1.1.2.2 | Tarifas |  | 1d | 2006-03-23 A | 2006-03-23 |  | 70% | 0.3d | 101d |  |  | Rec. Comercial | 8h | 5.6h |
| 7 | 1.1.2.3 | Precios |  | 1d | 2006-03-24 A | 2006-03-24 A | 6 | 100% |  |  |  |  | Rec. Comercial | 8h | 8h |
| 8 | 1.1.2.4 | Períodos |  | 1d | 2006-03-27 A | 2006-03-27 A | 7 | 100% |  |  |  |  |  |  |  |
| 9 | 1.1.2.5 | CAPS |  | 1d | 2006-03-28 A | 2006-03-28 A | 8 | 100% |  |  |  |  |  |  |  |
| 10 | 1.1.2.6 | Sesion Trabajo 1 | milestone | 0d | 2006-03-29 A | 2006-03-29 A | 9 | 100% |  |  |  | start no earlier than 2006-03-29 |  |  |  |
| 11 | 1.1.2.7 | **Clientes** |  | 1d | 2006-03-31 A | 2006-03-31 A |  | 100% |  |  |  |  |  |  |  |
| 12 | 1.1.2.7.1 | Convenios |  | 1d | 2006-03-31 A | 2006-03-31 A |  | 100% |  |  |  |  |  |  |  |
| 13 | 1.1.2.8 | Sesion Trabajo 2 | milestone | 0d | 2006-04-07 A | 2006-04-07 A | 12 | 100% |  |  |  | start no earlier than 2006-04-07 |  |  |  |
| 14 | 1.1.2.9 | Cotizaciones |  | 2d | 2006-04-03 A | 2006-04-04 A |  | 100% |  |  |  | start no earlier than 2006-04-03 |  |  |  |
| 15 | 1.1.2.10 | Reservaciones |  | 2d | 2006-04-05 A | 2006-04-06 | 14 | 90% | 0.2d | 91d |  |  |  |  |  |
| 16 | 1.1.2.11 | Consultas |  | 2d | 2006-04-07 A | 2006-04-10 A | 15 | 100% |  |  |  | start no earlier than 2006-04-07 | Rec. Comercial | 16h | 16h |
| 17 | 1.1.2.12 | Sesión Trabajo 3 | milestone | 0d | 2006-04-18 A | 2006-04-18 A |  | 100% |  |  |  | start no earlier than 2006-04-18 |  |  |  |
| 18 | 1.1.2.13 | Reportes |  | 1d? | 2006-04-11 A | 2006-04-11 | 16 | 25% | 0.75d? | 88d |  |  | Rec. Comercial | 8h | 2h |
| 19 | 1.1.2.14 | Alarmas |  | 1d? | 2006-04-12 A | 2006-04-12 A | 18 | 100% |  |  |  |  | Rec. Comercial | 8h | 8h |
| 20 | 1.1.2.15 | Sesión trabajo 4 | milestone | 0d | 2006-04-26 A | 2006-04-26 A |  | 100% |  |  |  | start no earlier than 2006-04-26 |  |  |  |
| 21 | 1.1.3 | **Operaciones** |  | 26d? | 2006-03-22 A | 2006-05-03 |  | 80% | 5.2d? | 77d |  |  |  | 245.33h | 197.07h |
| 22 | 1.1.3.1 | Estación |  | 0.5d | 2006-03-22 A | 2006-03-22 A |  | 100% |  |  |  | start no earlier than 2006-03-22 | Req. Operaciones | 4h | 4h |
| 23 | 1.1.3.2 | Impuestos |  | 0.5d | 2006-03-22 A | 2006-03-22 A |  | 100% |  |  |  | start no earlier than 2006-03-22 | Req. Operaciones | 4h | 4h |
| 24 | 1.1.3.3 | Parámetros |  | 0.5d | 2006-03-23 A | 2006-03-23 A |  | 100% |  |  |  | start no earlier than 2006-03-23 | Req. Operaciones | 4h | 4h |
| 25 | 1.1.3.4 | Preingreso |  | 0.5d | 2006-03-24 A | 2006-03-24 A |  | 100% |  |  |  | start no earlier than 2006-03-24 | Req. Operaciones | 4h | 4h |
| 26 | 1.1.3.5 | Sesion Trabajo 1 | milestone | 0d | 2006-03-29 A | 2006-03-29 A | 25 | 100% |  |  |  | start no earlier than 2006-03-29 |  |  |  |
| 27 | 1.1.3.6 | Ingreso |  | 0.5d | 2006-03-29 A | 2006-03-29 A | 26 | 100% |  |  |  |  | Req. Operaciones | 4h | 4h |
| 28 | 1.1.3.7 | Solic Traslado |  | 0.5d | 2006-03-27 A | 2006-03-27 A |  | 100% |  |  |  | start no earlier than 2006-03-27 | Req. Operaciones | 4h | 4h |
| 29 | 1.1.3.8 | Lista Negra |  | 1d? | 2006-03-27 A | 2006-03-27 A |  | 100% |  |  |  | start no earlier than 2006-03-27 | Req. Operaciones 2 | 8h | 8h |
| 30 | 1.1.3.9 | Trasaldo |  | 1d | 2006-03-28 A | 2006-03-28 A |  | 100% |  |  |  | start no earlier than 2006-03-28 | Req. Operaciones | 8h | 8h |
| 31 | 1.1.3.10 | Uso Vehículo |  | 1d? | 2006-03-29 A | 2006-03-29 A |  | 100% |  |  |  | start no earlier than 2006-03-29 | Req. Operaciones | 8h | 8h |
| 32 | 1.1.3.11 | Siniestro |  | 1d? | 2006-03-30 A | 2006-03-30 A |  | 100% |  |  |  | start no earlier than 2006-03-30 | Req. Operaciones | 8h | 8h |
| 33 | 1.1.3.12 | Punto Chequeo |  | 1d? | 2006-03-31 A | 2006-03-31 A |  | 100% |  |  |  | finish no earlier than 2006-03-31 | Req. Operaciones | 8h | 8h |
| 34 | 1.1.3.13 | Venta |  | 1d? | 2006-04-03 A | 2006-04-03 A |  | 100% |  |  |  | start no earlier than 2006-04-03 | Req. Operaciones | 8h | 8h |
| 35 | 1.1.3.14 | Apertura Contrato |  | 2d | 2006-03-29 A | 2006-03-30 |  | 75% | 0.5d | 93.9d | 0d | start no earlier than 2006-03-29 | Req. Operaciones 2 | 16h | 12h |
| 36 | 1.1.3.15 | Cierre Contrato |  | 2d | 2006-03-31 A | 2006-04-03 | 35 | 75% | 0.5d | 92.4d | 8d | start no earlier than 2006-03-31 | Req. Operaciones 2 | 16h | 12h |
| 37 | 1.1.3.16 | Extensión |  | 1d | 2006-04-07 A | 2006-04-07 A | 36 | 100% |  |  |  | start no earlier than 2006-04-07 | Req. Operaciones 2 | 8h | 8h |
| 38 | 1.1.3.17 | Sesion Trabajo 2 | milestone | 0d | 2006-04-07 A | 2006-04-07 A | 37 | 100% |  |  |  | start no earlier than 2006-04-07 |  |  |  |
| 39 | 1.1.3.18 | Cambio Unidad |  | 2d | 2006-04-11 A | 2006-04-12 | 38 | 70% | 0.6d | 87d |  | start no earlier than 2006-04-11 | Req. Operaciones 2 | 16h | 11.2h |
| 40 | 1.1.3.19 | Audtoría Contrato |  | 0.5d | 2006-04-17 A | 2006-04-17 A | 34 | 100% |  |  |  | start no earlier than 2006-04-14 | Req. Operaciones | 4h | 4h |
| 41 | 1.1.3.20 | Anulación Contratos |  | 0.5d | 2006-04-17 A | 2006-04-17 A | 40 | 100% |  |  |  | start no earlier than 2006-04-17 | Req. Operaciones | 4h | 4h |
| 42 | 1.1.3.21 | Facturación |  | 2d | 2006-04-18 A | 2006-04-20 | 36 | 90% | 0.2d | 82.6d | 0d | start no earlier than 2006-04-18 | Req. Operaciones 2 | 16h | 14.4h |
| 43 | 1.1.3.22 | Sesión Trabajo 3 | milestone | 0d | 2006-04-20 A | 2006-04-20 A | 42 | 100% |  |  |  | start no earlier than 2006-04-18 |  |  |  |
| 44 | 1.1.3.23 | Anulación Facturas |  | 0.5d | 2006-04-21 A | 2006-04-21 A | 43 | 100% |  |  |  | start no earlier than 2006-04-21 | Req. Operaciones | 4h | 4h |
| 45 | 1.1.3.24 | Facturación Adelantada |  | 2d | 2006-04-21 A | 2006-04-24 | 42 | 30% | 1.4d | 82d |  | start no earlier than 2006-04-21 | Req. Operaciones 2 | 16h | 4.8h |
| 46 | 1.1.3.25 | Consultas |  | 1d? | 2006-04-24 A | 2006-04-24 A |  | 100% |  |  |  | start no earlier than 2006-04-24 | Req. Operaciones | 8h | 8h |
| 47 | 1.1.3.26 | Comisiones operadores-freelance |  | 0.5d? | 2006-04-25 A | 2006-04-25 A |  | 100% |  |  |  | start no earlier than 2006-04-25 | Req. Operaciones | 4h | 4h |
| 48 | 1.1.3.27 | Costos Traslados |  | 0.5d | 2006-04-25 A | 2006-04-25 A | 45 | 100% |  |  |  | start no earlier than 2006-04-25 | Req. Operaciones 2 | 4h | 4h |
| 49 | 1.1.3.28 | Empleados por Ciudad |  | 0.5d | 2006-04-26 A | 2006-04-26 A |  | 100% |  |  |  | start no earlier than 2006-04-26 | Req. Operaciones | 4h | 4h |
| 50 | 1.1.3.29 | Reportes |  | 3d? | 2006-04-25 A | 2006-04-27 A | 41 | 100% |  |  |  | finish no earlier than 2006-04-27 | Req. Operaciones 2 [50%]; Req. Operaciones [50%] | 22.67h | 22.67h |
| 51 | 1.1.3.30 | Sesión trabajo 4 | milestone | 0d | 2006-04-26 A | 2006-04-26 A |  | 100% |  |  |  | start no earlier than 2006-04-26 |  |  |  |
| 52 | 1.1.3.31 | Alarmas |  | 1d | 2006-04-28 A | 2006-04-28 A |  | 100% |  |  |  | start no earlier than 2006-04-28 | Req. Operaciones | 8h | 8h |
| 53 | 1.1.3.32 | Estadísticas |  | 3d | 2006-04-27 | 2006-05-02 |  |  |  | 77d |  | start no earlier than 2006-04-27 | Req. Operaciones [50%]; Req. Operaciones 2 [50%] | 22.67h |  |
| 54 | 1.1.3.33 | Sesión Trabajo 5 | milestone | 0d | 2006-05-03 A | 2006-05-03 A |  | 100% |  |  |  | start no earlier than 2006-05-03 |  |  |  |

| ID | WBS | Task | Type | Duration | Start | Finish | Predecessors | Complete | Remaining | Total slack | Constraint | Resources | Work | Actual work |
| --- | --- | --- | --- | --- | --- | --- | --- | --- | --- | --- | --- | --- | --- | --- |
| 55 | 1.1.4 | **Mantenimiento** |  | 7d? | 2006-03-27 A | 2006-04-04 A |  | 100% |  |  |  |  | 56h | 56h |
| 56 | 1.1.4.1 | Ordenes de Trabajo |  | 3d | 2006-03-27 A | 2006-03-29 A |  | 100% |  |  | finish no earlier than 2006-03-29 | Rec. Manten | 24h | 24h |
| 57 | 1.1.4.2 | Solicitud Productos |  | 1d? | 2006-03-30 A | 2006-03-30 A | 56 | 100% |  |  |  | Rec. Manten | 8h | 8h |
| 58 | 1.1.4.3 | Aprobación pedidos |  | 1d? | 2006-03-31 A | 2006-03-31 A | 57 | 100% |  |  |  | Rec. Manten | 8h | 8h |
| 59 | 1.1.4.4 | Consultas |  | 1d | 2006-04-03 A | 2006-04-03 A | 58 | 100% |  |  |  | Rec. Manten | 8h | 8h |
| 60 | 1.1.4.5 | Alarmas |  | 1d? | 2006-04-04 A | 2006-04-04 A | 59 | 100% |  |  |  | Rec. Manten | 8h | 8h |
| 61 | 1.1.4.6 | Sesion Trabajo 1 | milestone | 0d | 2006-03-29 A | 2006-03-29 A |  | 100% |  |  | start no earlier than 2006-03-29 |  |  |  |
| 62 | 1.1.5 | **Administrativo** |  | 2d? | 2006-04-27 A | 2006-04-28 A |  | 100% |  |  |  |  | 8h | 8h |
| 63 | 1.1.5.1 | Reportes |  | 1d? | 2006-04-27 A | 2006-04-27 A |  | 100% |  |  | start no earlier than 2006-04-27 | Rea. Admin | 8h | 8h |
| 64 | 1.1.5.2 | Sesion Trabajo 1 | milestone | 0d | 2006-04-27 A | 2006-04-27 A | 63 | 100% |  |  | start no earlier than 2006-03-29 |  |  |  |
| 65 | 1.1.5.3 | Alarmas |  | 1d? | 2006-04-28 A | 2006-04-28 A | 64 | 100% |  |  |  |  |  |  |
| 66 | 1.1.6 | **Ajsutes sesión 5** |  | 1d? | 2006-05-10 A | 2006-05-10 A |  | 100% |  |  |  |  |  |  |
| 67 | 1.1.6.1 | Sesion Trabajo 6 |  | 1d? | 2006-05-10 A | 2006-05-10 A |  | 100% |  |  | start no earlier than 2006-05-10 |  |  |  |
| 68 | 1.2 | **Interfaz Génesis- Great Plains** |  | 39d | 2006-05-17 A | 2006-07-10 |  | 6% | 36.81d | 28d |  |  | 448h | 8.4h |
| 69 | 1.2.1 | Definiciones detalladas de Diseño |  | 2d | 2006-05-17 A | 2006-05-18 |  | 80% | 0.4d | 65d | start no earlier than 2006-05-17 |  |  |  |
| 70 | 1.2.2 | **Cambios en Génesis** |  | 3d | 2006-05-19 A | 2006-05-23 |  | 35% | 1.95d | 62d |  |  | 24h | 8.4h |
| 71 | 1.2.2.1 | Banco |  | 3d | 2006-05-19 A | 2006-05-23 |  | 35% | 1.95d | 62d | start no earlier than 2006-05-19 | R4 | 24h | 8.4h |
| 72 | 1.2.3 | **Contrato** |  | 8d | 2006-05-25 | 2006-06-05 |  |  |  | 53d |  |  | 64h |  |
| 73 | 1.2.3.1 | Contrato, Validaci'on del Saldo de cliente y botón que muestre el crédito del cliente si este tiene crédito |  | 2d | 2006-05-25 | 2006-05-26 |  |  |  | 59d | start no earlier than 2006-05-25 | R4 | 16h |  |
| 74 | 1.2.3.2 | Forma de Pago con TDC, Retención ISLR en Contrato |  | 4d | 2006-05-29 | 2006-06-01 |  |  |  | 55d | start no earlier than 2006-05-29 | R4 | 32h |  |
| 75 | 1.2.3.3 | Ingreso/Modificacion de Cliente |  | 2d | 2006-06-02 | 2006-06-05 |  |  |  | 53d | start no earlier than 2006-06-02 | R4 | 16h |  |
| 76 | 1.2.4 | **Inventario** |  | 18d | 2006-05-22 | 2006-06-14 |  |  |  | 46d |  |  | 144h |  |
| 77 | 1.2.4.1 | Descarga de productos |  | 5d | 2006-05-22 | 2006-05-26 |  |  |  | 59d | start no earlier than 2006-05-22 | R5 | 40h |  |
| 78 | 1.2.4.2 | Devolución Productos |  | 4d | 2006-05-29 | 2006-06-01 |  |  |  | 55d | start no earlier than 2006-05-29 | R5 | 32h |  |
| 79 | 1.2.4.3 | Reportes/Consulta inventario |  | 5d | 2006-06-02 | 2006-06-08 |  |  |  | 50d | start no earlier than 2006-06-02 | R5 | 40h |  |
| 80 | 1.2.4.4 | Facturación tercero |  | 4d | 2006-06-09 | 2006-06-14 |  |  |  | 46d | start no earlier than 2006-06-09 | R5 | 32h |  |

Notes:
- 71: Incluir nueva tabla para manejar nueva facilidad de puntos de venta, con los siguientes campos: Nombre, Código, Retención, Comisión. Desarrollar el programa para ingresar, modificar y consultar bancos
- 73: Agregar la valdiación del saldo y lod días de crédito y la autorización en la apertura del contrato
- 74: Incluir esta forma de pago en Factura de alquiler, facturas de siniestro y venta de unidades. Implica cambioes en ESTACIO agregando puntos de venta y CAJA(ID Chequera)
- 75: Modificar los programas de contrato para permitir incluir estos campos ID class. / Adicionalmente hay que modificar los programas de reserva y contrato para que inserte la fecha de creaci'on del registro del cliente cuando sea el caso

| ID | WBS | Task | Type | Duration | Start | Finish | Predecessors | Complete | Remaining | Total slack | Free slack | Constraint | Resources | Work | Actual work |
| --- | --- | --- | --- | --- | --- | --- | --- | --- | --- | --- | --- | --- | --- | --- | --- |
| 81 | 1.2.5 | **Facturación (todas)** |  | 3d | 2006-06-15 | 2006-06-19 |  |  |  | 43d |  |  |  |  |  |
| 82 | 1.2.5.1 | Manejo de tabla de conceptos |  | 3d | 2006-06-15 | 2006-06-19 |  |  |  | 43d |  | start no earlier than 2006-06-15 |  |  |  |
| 83 | 1.2.6 | **Reservación** |  | 4d | 2006-06-20 | 2006-06-23 |  |  |  | 39d |  |  |  |  |  |
| 84 | 1.2.6.1 | Retención de ISLR, Comisión |  | 2d | 2006-06-20 | 2006-06-21 |  |  |  | 41d |  | start no earlier than 2006-06-20 |  |  |  |
| 85 | 1.2.6.2 | Ingreso/Modificacion de Cliente |  | 2d | 2006-06-22 | 2006-06-23 |  |  |  | 39d |  | start no earlier than 2006-06-22 |  |  |  |
| 86 | 1.2.7 | Incoporar Nuevos Campos DR |  | 1d | 2006-05-24 | 2006-05-24 |  |  |  | 61d |  | start no earlier than 2006-05-24 |  |  |  |
| 87 | 1.2.8 | DR Interfaz para cliente/Proveedores |  | 1d | 2006-06-27 A | 2006-06-27 |  | 10% | 0.9d | 31d | 0d | start no earlier than 2006-06-27 |  |  |  |
| 88 | 1.2.9 | Pruebas y Ajustes |  | 6d | 2006-06-28 | 2006-07-05 | 87 |  |  | 31d |  |  | R4; R5; Usuario | 144h |  |
| 89 | 1.2.10 | Implantación Génesis ambiente de producción |  | 3d | 2006-07-06 | 2006-07-10 |  |  |  | 28d |  | start no earlier than 2006-07-06 | R4; R5; Usuario | 72h |  |
| 90 | 1.3 | **Carga Data Producción** |  | 18d? | 2006-05-02 A | 2006-05-25 |  | 44% | 10d? | 60d |  |  |  | 32h | 32h |
| 91 | 1.3.1 | Carga de usuarios |  | 1d | 2006-05-11 A | 2006-05-11 A |  | 100% |  |  |  | start no earlier than 2006-05-11 |  |  |  |
| 92 | 1.3.2 | Preparacion hojas excel |  | 4d? | 2006-05-02 A | 2006-05-05 A |  | 100% |  |  |  | finish no earlier than 2006-05-05 | E. Araujo | 32h | 32h |
| 93 | 1.3.3 | Revisión Hoja excel con data del cliente |  | 1d | 2006-05-08 A | 2006-05-08 A | 92 | 100% |  |  |  |  |  |  |  |
| 94 | 1.3.4 | Carga de clientes |  | 4d | 2006-05-09 A | 2006-05-12 | 93 | 25% | 3d | 69d |  |  |  |  |  |
| 95 | 1.3.5 | Carga de las tablas bases |  | 2d | 2006-05-09 A | 2006-05-10 A |  | 100% |  |  |  | start no earlier than 2006-05-09 |  |  |  |
| 96 | 1.3.6 | Carga de comercial en sistema |  | 9d? | 2006-05-15 | 2006-05-25 |  |  |  | 60d |  | finish no earlier than 2006-05-25 |  |  |  |
| 97 | 1.3.7 | Revision y Ajustes Carga |  | 6d? | 2006-05-18 A | 2006-05-25 |  | 50% | 3d? | 60d |  | start no earlier than 2006-05-18 |  |  |  |
| 98 | 1.4 | **Contingencia** |  | 12d? | 2006-05-25 | 2006-06-09 |  |  |  | 49d |  |  |  | 80h |  |
| 99 | 1.4.1 | Comunicar a personal de contingencia responsabilidad en resvisi'on del proceso |  | 1d? | 2006-05-25 | 2006-05-25 |  |  |  | 60d |  | start no earlier than 2006-05-25 | E. Araujo | 8h |  |
| 100 | 1.4.2 | Revisión Contingencia |  | 3d | 2006-05-29 | 2006-05-31 |  |  |  | 56d |  | start no earlier than 2006-05-29 | R1; Usuario; E. Araujo | 72h |  |
| 101 | 1.4.3 | Entrega de Nuevo plan contingencia | milestone | 0d? | 2006-05-31 | 2006-05-31 |  |  |  | 57d |  | start no earlier than 2006-05-31 | Usuario; E. Araujo |  |  |
| 102 | 1.4.4 | Comunicar a los counters nuevo Plan de Continegncia |  | 4d? | 2006-06-06 | 2006-06-09 |  |  |  | 49d |  | finish no earlier than 2006-06-09 |  |  |  |
| 103 | 1.5 | **Prueba Piloto** |  | 38d? | 2006-05-04 A | 2006-06-27 |  | 8% | 35.15d? | 38d |  |  |  | 24h | 12h |
| 104 | 1.5.1 | Logística de traslado de personal |  | 1d? | 2006-05-23 A | 2006-05-23 |  | 25% | 0.75d? | 62d |  | start no earlier than 2006-05-23 | E. Araujo | 8h | 2h |
| 105 | 1.5.2 | Logística salones y refrigerios |  | 1d? | 2006-05-04 A | 2006-05-04 A |  | 100% |  |  |  | start no earlier than 2006-05-04 | E.Araujo | 8h | 8h |
| 106 | 1.5.3 | Lista de personal a adiestrar por sesión |  | 1d? | 2006-05-23 A | 2006-05-23 |  | 25% | 0.75d? | 61d | 8d | start no earlier than 2006-05-23 | E.Araujo | 8h | 2h |
| 107 | 1.5.4 | Preparación Adiestramiento |  | 1d? | 2006-06-01 | 2006-06-01 |  |  |  | 55d |  | start no earlier than 2006-06-01 |  |  |  |
| 108 | 1.5.5 | Adiestramiento 1 |  | 1d | 2006-06-05 | 2006-06-05 | 106 |  |  | 53d |  | start no earlier than 2006-06-05 |  |  |  |
| 109 | 1.5.6 | Adiestramiento 2 |  | 1d? | 2006-06-06 | 2006-06-06 |  |  |  | 52d |  | start no earlier than 2006-06-06 |  |  |  |
| 110 | 1.5.7 | Carga Datos Prueba1 |  | 1d | 2006-06-09 | 2006-06-09 |  |  |  | 49d |  | start no earlier than 2006-06-09 |  |  |  |
| 111 | 1.5.8 | Carga Datos Prueba2 |  | 1d? | 2006-06-16 | 2006-06-16 |  |  |  | 44d |  | start no earlier than 2006-06-16 |  |  |  |
| 112 | 1.5.9 | Soporte1 pruebas |  | 6d | 2006-06-08 | 2006-06-15 |  |  |  | 45d |  | start no earlier than 2006-06-08 |  |  |  |
| 113 | 1.5.10 | Soporte 2 pruebas |  | 6d | 2006-06-19 | 2006-06-26 |  |  |  | 38d |  | start no earlier than 2006-06-19 |  |  |  |
| 114 | 1.5.11 | Entrega de Informe del cliente | milestone | 0d | 2006-06-27 | 2006-06-27 |  |  |  | 38d |  | start no earlier than 2006-06-27 |  |  |  |

Notes:
- 88: Pruebas de la interfaz
- 92: - responsabilidad del usuario
- 99: Enviar un email a todos los que participarán en esta sesión de trabajo / Contar con el proceso actual de contingencia que debe traer el equipo de proceso y de operaciones . / Revisar el plan de contingencia actual, adpartarlo y generar el nuevo plan
- 100: Se apoyará al personal de proceso y de HERTZ en la adpatación de nuevo plan de contingencia
- 101: El personal de proceso de la Corporacion deberá entregar a operaciones HERTZ el nuevo plan de contingencia / Los usuarios deberán comunicar a las áreas la nueva contingencia
- 105: E. Araujo cordinará con M. Saavedra
- 106: E. Araujo entregará la lista del personal por sesión
- 114: El usuario entregará a GWT un informe con los resultados de las pruebas piloto

| ID | WBS | Task | Duration | Start | Finish | Predecessors | Complete | Remaining | Total slack | Free slack | Constraint | Resources | Work | Actual work |
| --- | --- | --- | --- | --- | --- | --- | --- | --- | --- | --- | --- | --- | --- | --- |
| 115 | 1.6 | **Adiestramiento** | 39d? | 2006-05-16 A | 2006-07-07 |  | 2% | 38.11d? | 29d |  |  |  | 16h | 2h |
| 116 | 1.6.1 | **Adiestramiento Nuevos Procesos** | 1d? | 2006-05-16 A | 2006-05-16 |  | 13% | 0.88d? | 67d |  |  |  | 16h | 2h |
| 117 | 1.6.1.1 | Reunión de trabajo revisión de procesos | 1d? | 2006-05-16 | 2006-05-16 |  |  |  | 59d | 30d | start no earlier than 2006-05-16 | E. Araujo | 8h |  |
| 118 | 1.6.1.2 | Preparar logística de adiestramiento de personal | 1d? | 2006-05-16 A | 2006-05-16 |  | 25% | 0.75d? | 67d |  | start no earlier than 2006-05-16 | E. Araujo | 8h | 2h |
| 119 | 1.6.2 | **Adiestramiento Génesis** | 9d? | 2006-06-27 | 2006-07-07 |  |  |  | 29d |  |  |  |  |  |
| 120 | 1.6.2.1 | Preparación | 1d? | 2006-06-27 | 2006-06-27 |  |  |  | 37d |  | start no earlier than 2006-06-27 |  |  |  |
| 121 | 1.6.2.2 | Adiestramientos | 8d | 2006-06-28 | 2006-07-07 | 117 |  |  | 29d |  | start no earlier than 2006-06-28 |  |  |  |
| 122 | 1.7 | Carga Día D-1 | 1d? | 2006-07-19 | 2006-07-19 |  |  |  | 21d |  | start no earlier than 2006-07-19 | R1; R2; Usuario | 24h |  |
| 123 | 1.8 | Implantación | 1d | 2006-07-20 | 2006-07-20 |  |  |  | 20d |  | start no earlier than 2006-07-20 | R1; R2; Usuario | 24h |  |
| 124 | 1.9 | Soporte Post-Implantación | 20d | 2006-07-21 | 2006-08-17 |  |  |  | 0d |  | start no earlier than 2006-07-21 |  |  |  |

Notes:
- 117: - Revisar con el personal de proceso más los usuarios funcionales todo los cambios que se deben divulgar a los usaurios de Génesis / - preparar material con el proceso para ser entregado a los usuarios
- 118: - Salón de adiestramiento listo / - Quiénes son las persona a adiestrar por sesión / - Traslado del personal (donde aplique) / - Logística de alojamiento y comida / - Duración del curso / - Responsable: Tania
