# Plan New Light International_2005Sep29

Schedule from MS Project, 2006-07-03 to 2006-09-18.
GSM

## Calendars

- Standard: Mon-Fri 08:00-12:00, 13:00-17:00; Sat-Sun off.

## Resources

| Resource | Group |
| --- | --- |
| GWT Socio | GWT |
| GWT Lider Proyecto | GWT |
| GWT Analista 1 | GWT |
| GWT Analista 2 | GWT |
| DC Diseñador | DC |
| DC Lider Proyecto | DC |
| TN Lider Proyecto | TN |
| GWT Operaciones 1 | GWT |
| TN Operación 1 | TN |
| GWT Programador 1 | GWT |
| GWT Programador 2 | GWT |
| GS1,GLP |  |
| GS1,GLP,TLP |  |
| GLP,GA1,GA2 |  |
| TLP,DLP |  |
| GS1,TO1,GO1 |  |
| GS1,GO1 |  |
| GO1,GLP |  |
| DLP,TLP |  |
| GLP,GA1 |  |
| TLP,.DLP |  |
| GLP,GA2 |  |
| GLP,GP2 |  |
| GP1,GA1 |  |
| GLP,GP1 |  |
| GA1,GA2 |  |
| GLP,GA1GLP |  |
| GA2,DLP,TLP |  |
| GLP,DLP,TLP, |  |
| GLP,DLP,TLP |  |
| ¨GLP |  |
| GA2,GA1 |  |
| GA! |  |
| 1 |  |
| GA2,GO1 |  |
| GA1,GO1 |  |
| GLP,TLP,DLP |  |
| GLP,GA1,GA2,GO1 |  |

## Schedule

| ID | WBS | Task | Duration | Start | Finish | Predecessors | Total slack | Free slack | Constraint | Resources | Work |
| --- | --- | --- | --- | --- | --- | --- | --- | --- | --- | --- | --- |
| 1 | GWT_DC_01.1 | **Proyecto DiChis** | 55.35d? | 2006-07-03 08:00 | 2006-09-18 10:48 |  | 0d |  |  |  | 2697.2h |
| 2 | GWT_DC_01.1.1 | Gerencia de Proyectos | 416h? | 2006-07-03 08:00 | 2006-09-12 17:00 |  | 3.35d |  | finish no earlier than 2006-09-12 17:00 | GS1,GLP,TLP | 416h |
| 3 | GWT_DC_01.1.32 | **Pruebas en ambiente de desarrollo** | 52d? | 2006-07-03 08:00 | 2006-09-12 17:00 |  | 3.35d |  |  |  | 752h |
| 4 | GWT_DC_01.1.32.3 | Internas | 416h? | 2006-07-03 08:00 | 2006-09-12 17:00 |  | 3.35d |  | finish no earlier than 2006-09-12 17:00 | GLP,GA1,GA2 | 416h |
| 5 | GWT_DC_01.1.32.4 | De certificación | 168h? | 2006-07-03 08:00 | 2006-07-31 17:00 |  | 34.35d |  | start no earlier than 2006-07-03 08:00 | TLP,DLP | 168h |
| 6 | GWT_DC_01.1.32.5 | Ajustes tras pruebas | 168h? | 2006-07-03 08:00 | 2006-07-31 17:00 |  | 34.35d |  | start no earlier than 2006-07-03 08:00 | GLP,GA1,GA2 | 168h |
| 7 | GWT_DC_01.1.2 | **Operación, Mantenimiento y Soporte** | 3.25d? | 2006-07-03 08:00 | 2006-07-06 10:00 |  | 0d |  |  |  | 54h |
| 8 | GWT_DC_01.1.2.3 | Actualización de documento de configuración de servidores | 2h? | 2006-07-03 08:00 | 2006-07-03 10:00 |  | 0d |  |  | GS1,TO1,GO1 | 2h |
| 9 | GWT_DC_01.1.2.2 | Adquisición de servicios de hosting | 8h? | 2006-07-03 10:00 | 2006-07-04 10:00 | 8 | 0d |  |  | DC Lider Proyecto | 8h |
| 10 | GWT_DC_01.1.2.4 | Adquisición e Instalación de PDFlib | 4h? | 2006-07-04 10:00 | 2006-07-04 15:00 | 9 | 1d | 0d |  | GS1,GO1 | 4h |
| 11 | GWT_DC_01.1.2.5 | Configuración y Prueba | 4h? | 2006-07-04 15:00 | 2006-07-05 10:00 | 10 | 1d |  |  | GWT Operaciones 1 | 4h |
| 12 | GWT_DC_01.1.2.6 | Instalación de N2C y WIB | 8h? | 2006-07-04 10:00 | 2006-07-05 10:00 | 9 | 0d |  |  | GWT Operaciones 1 | 8h |
| 13 | GWT_DC_01.1.2.7 | Instalación de librerias de manipulación de imágenes (Image Magick y GD) | 4h? | 2006-07-04 10:00 | 2006-07-04 15:00 | 9 | 1.5d |  |  | GWT Operaciones 1 | 4h |
| 14 | GWT_DC_01.1.2.8 | Investigación y Adquisición de versión JAVA de Aurigma | 8h? | 2006-07-04 10:00 | 2006-07-05 10:00 | 9 | 0d |  |  | GS1,GLP | 8h |
| 15 | GWT_DC_01.1.2.9 | Configuración y Pruebas de versión JAVA de Aurigma | 8h? | 2006-07-05 10:00 | 2006-07-06 10:00 | 14 | 0d |  |  | GO1,GLP | 8h |
| 16 | GWT_DC_01.1.2.10 | Limpieza del URL para eliminar ZZZ/…/… | 8h? | 2006-07-05 10:00 | 2006-07-06 10:00 | 12 | 0d |  |  | GWT Operaciones 1 | 8h |
| 17 | GWT_DC_01.1.32 | **Desarrollo** | 32.85d? | 2006-07-06 10:00 | 2006-08-22 08:48 | 7 | 0d |  |  |  | 1285.6h |
| 18 | GWT_DC_01.1.32.1 | **Migración BD PHS a Servidor de desarrollo** | 2d? | 2006-07-06 10:00 | 2006-07-10 10:00 |  | 0d |  |  |  | 26.4h |
| 19 | GWT_DC_01.1.32.1.1 | Reingeniería del Modelo de datos de BD incorporando ajustes para manejo de selecciones y blogs. | 8h? | 2006-07-06 10:00 | 2006-07-07 10:00 |  | 0d |  |  | GLP,GA1,GA2 | 8h |
| 20 | GWT_DC_01.1.32.1.2 | Planificación de la migración | 4h? | 2006-07-06 10:00 | 2006-07-06 15:00 |  | 0.5d |  |  | GLP,GA1 | 4h |
| 21 | GWT_DC_01.1.32.1.3 | Creación de tablas N2C a imagen de PHS con los cambios. OJO: e-MM Català en TRADUCCIONES | 8h? | 2006-07-07 10:00 | 2006-07-10 10:00 | 20, 19 | 0d |  |  | GWT Analista 2 [80%] | 6.4h |
| 22 | GWT_DC_01.1.32.1.4 | Traducción de términos $MM. Manejo de catalán, español e inglés en principio | 8h? | 2006-07-06 10:00 | 2006-07-07 10:00 |  | 1d |  |  | DLP,TLP | 8h |
| 23 | GWT_DC_01.1.32.2 | **Migración aplicación PHS** | 4d? | 2006-07-10 10:00 | 2006-07-14 10:00 | 18 | 0d |  |  |  | 44.8h |
| 24 | GWT_DC_01.1.32.2.1 | Construcción de mapa de navegación de PHS | 8h? | 2006-07-10 10:00 | 2006-07-11 10:00 |  | 0d |  |  | GLP,GA1,GA2 | 8h |
| 25 | GWT_DC_01.1.32.2.2 | Casos de Uso PHS | 8h? | 2006-07-11 10:00 | 2006-07-12 10:00 | 24 | 0d |  |  | GLP,GA1,GA2 | 8h |
| 26 | GWT_DC_01.1.32.2.3 | Adaptación de Casos de Uso PHS incorporando DiChis | 16h? | 2006-07-12 10:00 | 2006-07-14 10:00 | 25 | 0d |  |  | GLP,GA1,GA2 | 16h |
| 27 | GWT_DC_01.1.32.2.4 | Pantalla de unificación de funcionalidades de back office -al estilo WIB- Start page | 8h? | 2006-07-10 10:00 | 2006-07-11 10:00 |  | 3d |  |  | GWT Analista 1 [80%] | 6.4h |
| 28 | GWT_DC_01.1.32.2.5 | Verificación de funcionalidades de B.O. que se pueden probar hasta este punto. | 8h? | 2006-07-10 10:00 | 2006-07-11 10:00 |  | 3d |  |  | GWT Analista 2 [80%] | 6.4h |

Notes:
- 1: Generales / ·Compatibilidad con Firefox / ·Definición de templates para puesta al aire / ·Redefinición del tamaño de las fotos de trabajo / ·Redefinición del tamaño de thumbnail (para visualización y construcción de productos) / ·Traducción de términos $MM. Manejo de catalán y español en principio / ·Documentar código / ·Las consideraciones de L&F estan sujetos a cambios por desconocimiento del estilo del diseñador

| ID | WBS | Task | Duration | Start | Finish | Predecessors | Total slack | Free slack | Resources | Work |
| --- | --- | --- | --- | --- | --- | --- | --- | --- | --- | --- |
| 29 | GWT_DC_01.1.32.3 | **Revisión y ajuste de programas recurrentes** | 2.5d? | 2006-07-14 10:00 | 2006-07-18 15:00 | 23 | 24.35d |  |  | 16h |
| 30 | GWT_DC_01.1.32.3.1 | arriba | 5h? | 2006-07-14 10:00 | 2006-07-14 16:00 |  | 24.35d | 0d | GWT Lider Proyecto [80%] | 4h |
| 31 | GWT_DC_01.1.32.3.2 | cabecera | 10h? | 2006-07-14 16:00 | 2006-07-18 09:00 | 30 | 24.35d | 0d | GWT Lider Proyecto [80%] | 8h |
| 32 | GWT_DC_01.1.32.3.3 | pie | 5h? | 2006-07-18 09:00 | 2006-07-18 15:00 | 31 | 24.35d |  | GWT Lider Proyecto [80%] | 4h |
| 33 | GWT_DC_01.1.32.4 | Definición de L&F Lineamientos a seguir en el site (reglas generales) | 8h? | 2006-07-06 10:00 | 2006-07-07 10:00 |  | 31.85d |  | DC Diseñador | 8h |
| 34 | GWT_DC_01.1.32.5 | **Ajuste de páginas de contenido** | 5.25d? | 2006-07-14 10:00 | 2006-07-21 12:00 | 23 | 21.6d |  |  | 42h |
| 35 | GWT_DC_01.1.32.5.1 | Definición de L&F | 8h? | 2006-07-14 10:00 | 2006-07-17 10:00 |  | 21.6d | 0d | DC Diseñador | 8h |
| 36 | GWT_DC_01.1.32.5.2 | Ajuste de L&F | 10h? | 2006-07-17 10:00 | 2006-07-18 12:00 | 35 | 21.6d | 0d | GWT Programador 1 | 10h |
| 37 | GWT_DC_01.1.7.3 | Actualización del contenido (ver anexo). Considerar mecanismo para multiidioma | 24h? | 2006-07-18 13:00 | 2006-07-21 12:00 | 36 | 21.6d |  | TLP,.DLP | 24h |
| 38 | GWT_DC_01.1.32.6 | **Ajuste de páginas con párrafos de aplicación** | 3.25d? | 2006-07-14 10:00 | 2006-07-19 12:00 | 23 | 23.6d |  |  | 30.8h |
| 39 | GWT_DC_01.1.8.1 | Definición de L&F | 8h? | 2006-07-14 10:00 | 2006-07-17 10:00 |  | 23.6d | 0d | DC Diseñador | 8h |
| 40 | GWT_DC_01.1.8.2 | Ajuste de L&F | 10h? | 2006-07-17 10:00 | 2006-07-18 12:00 | 39 | 23.6d | 0d | GWT Programador 2 | 10h |
| 41 | GWT_DC_01.1.8.3 | Revisión FAQ, Boletin | 8h? | 2006-07-18 13:00 | 2006-07-19 12:00 | 40 | 23.6d |  | GWT Analista 1 [80%] | 6.4h |
| 42 | GWT_DC_01.1.8.4 | Revisión de registro de usuarios | 8h? | 2006-07-18 13:00 | 2006-07-19 12:00 | 40 | 23.6d |  | GWT Analista 2 [80%] | 6.4h |
| 43 | GWT_DC_01.1.32.7 | **Módulo de Admin de Cliente (MAC)** | 4d? | 2006-07-14 10:00 | 2006-07-20 10:00 | 23 | 22.85d |  |  | 27.2h |
| 44 | GWT_DC_01.1.9.1 | Definición de L&F | 8h? | 2006-07-14 10:00 | 2006-07-17 10:00 |  | 22.85d | 0d | DC Diseñador | 8h |
| 45 | GWT_DC_01.1.9.2 | Ajuste de L&F | 24h? | 2006-07-17 10:00 | 2006-07-20 10:00 | 44 | 22.85d |  | GWT Lider Proyecto [80%] | 19.2h |
| 46 | GWT_DC_01.1.32.8 | **Upload de fotos** | 2.75d? | 2006-07-14 10:00 | 2006-07-18 17:00 | 23 | 0d |  |  | 30h |
| 47 | GWT_DC_01.1.32.8.1 | Definición de L&F | 8h? | 2006-07-14 10:00 | 2006-07-17 10:00 |  | 0.75d |  | DC Diseñador | 8h |
| 48 | GWT_DC_01.1.10.2 | Incorporación de Upload Aurigma en versión java. Considerar tiempo de investigación. | 6h? | 2006-07-14 10:00 | 2006-07-14 17:00 |  | 0d |  | GLP,GA2 | 6h |
| 49 | GWT_DC_01.1.10.3 | Desactivar botón de envío por espacio insuficiente. | 2h? | 2006-07-17 08:00 | 2006-07-17 10:00 | 48 | 1.75d |  | GWT Lider Proyecto [80%] | 1.6h |
| 50 | GWT_DC_01.1.10.4 | Extraer metadata de las fotos al momento de la subida y asociarla al registro de la foto en BD (requiere investigación) | 8h? | 2006-07-17 08:00 | 2006-07-17 17:00 | 48 | 0d |  | GWT Analista 1 [80%] | 6.4h |
| 51 | GWT_DC_01.1.10.5 | Ajuste de L&F (versión java y tradicional) | 8h? | 2006-07-18 08:00 | 2006-07-18 17:00 | 47, 50 | 0d |  | GWT Programador 1 | 8h |
| 52 | GWT_DC_01.1.32.9 | **Administración de Carpetas** | 3d? | 2006-07-19 08:00 | 2006-07-21 17:00 | 46 | 3.6d | 0d |  | 40h |
| 53 | GWT_DC_01.1.11.1 | Definición de L&F | 8h? | 2006-07-19 08:00 | 2006-07-19 17:00 |  | 3.6d | 0d | DC Diseñador | 8h |
| 54 | GWT_DC_01.1.11.2 | Revisión de opciones de administración de carpetas: renombrar carpeta, cambiar portada, copiar carpeta, eliminar carpeta | 8h? | 2006-07-19 08:00 | 2006-07-19 17:00 |  | 4.6d | 0d | GWT Lider Proyecto [80%] | 6.4h |
| 55 | GWT_DC_01.1.11.3 | Verificación de nombre de carpeta física versus nombre interno para evitar aborto de mkdir | 8h? | 2006-07-20 08:00 | 2006-07-20 17:00 | 54 | 4.6d |  | GWT Analista 2 [80%] | 6.4h |
| 56 | GWT_DC_01.1.11.4 | Eliminación de opción de compartir a nivel de carpeta | 4h? | 2006-07-19 08:00 | 2006-07-19 12:00 |  | 6.1d |  | GWT Analista 1 [80%] | 3.2h |
| 57 | GWT_DC_01.1.11.5 | Ajuste de L&F | 16h? | 2006-07-20 08:00 | 2006-07-21 17:00 | 53 | 3.6d |  | GLP,GP2 | 16h |

Notes:
- 34: En catalan, español e ingles

| ID | WBS | Task | Duration | Start | Finish | Predecessors | Total slack | Free slack | Resources | Work |
| --- | --- | --- | --- | --- | --- | --- | --- | --- | --- | --- |
| 58 | GWT_DC_01.1.32.10 | **Administración de imágenes en carpetas** | 3d? | 2006-07-19 08:00 | 2006-07-21 17:00 | 46 | 0d |  |  | 56h |
| 59 | GWT_DC_01.1.12.1 | Definición de L&F | 8h? | 2006-07-19 08:00 | 2006-07-19 17:00 |  | 21.5d | 0d | DC Diseñador | 8h |
| 60 | GWT_DC_01.1.12.2 | Visualización de fotos: tamaño de visualización más grande, mostrar descripción de la foto. | 16h? | 2006-07-19 08:00 | 2006-07-20 17:00 |  | 0d |  | GWT Analista 2 [80%] | 12.8h |
| 61 | GWT_DC_01.1.12.3 | Revisión de opciones de administración de imágenes: renombrar imagen, copiar imagen, mover imagen, eliminar imagen, editar imagen. | 8h? | 2006-07-21 08:00 | 2006-07-21 17:00 | 60 | 21.1d |  | GWT Lider Proyecto [80%] | 6.4h |
| 62 | GWT_DC_01.1.12.4 | **Detalle de foto** | 1d? | 2006-07-21 08:00 | 2006-07-21 17:00 | 60 | 21.1d |  |  | 16h |
| 63 | GWT_DC_01.1.12.4.1 | Edición de datos de foto | 8h? | 2006-07-21 08:00 | 2006-07-21 17:00 |  | 21.1d |  | GWT Analista 1 [80%] | 6.4h |
| 64 | GWT_DC_01.1.12.4.2 | Descarga de foto original | 2h? | 2006-07-21 08:00 | 2006-07-21 10:00 |  | 21.85d |  | GWT Analista 1 [80%] | 1.6h |
| 65 | GWT_DC_01.1.12.4.3 | Click sobre foto lleva a edición avanzada | 2h? | 2006-07-21 08:00 | 2006-07-21 10:00 |  | 21.85d |  | GWT Analista 1 [80%] | 1.6h |
| 66 | GWT_DC_01.1.12.4.4 | Incluir metadata en datos de foto desplegada | 8h? | 2006-07-21 08:00 | 2006-07-21 17:00 |  | 21.1d |  | GWT Analista 1 [80%] | 6.4h |
| 67 | GWT_DC_01.1.12.5 | Ajuste de L&F | 12.8h? | 2006-07-20 08:00 | 2006-07-21 13:48 | 59 | 21.5d |  | GP1,GA1 | 12.8h |
| 68 | GWT_DC_01.1.32.11 | **Edición de imágenes** | 3.8d? | 2006-07-21 08:00 | 2006-07-26 15:24 | 60 | 0d |  |  | 32h |
| 69 | GWT_DC_01.1.13.1 | Definición de L&F | 6.4h? | 2006-07-21 08:00 | 2006-07-21 15:24 |  | 0d |  | DC Diseñador | 6.4h |
| 70 | GWT_DC_01.1.13.2 | Revisión de edición avanzada de fotos: Ojos rojos, Rotación, Efectos -blanco y negro / sepia- | 8h? | 2006-07-21 08:00 | 2006-07-21 17:00 |  | 2.8d |  | GWT Lider Proyecto [80%] | 6.4h |
| 71 | GWT_DC_01.1.13.3 | Ajuste de L&F | 24h? | 2006-07-21 15:24 | 2006-07-26 15:24 | 69 | 0d |  | GWT Analista 2 [80%] | 19.2h |
| 72 | GWT_DC_01.1.32.12 | **Administración de cuenta del cliente** | 4d? | 2006-07-14 10:00 | 2006-07-20 10:00 | 23 | 22.85d |  |  | 27.2h |
| 73 | GWT_DC_01.1.14.1 | Definición de L&F | 8h? | 2006-07-14 10:00 | 2006-07-17 10:00 |  | 22.85d | 0d | DC Diseñador | 8h |
| 74 | GWT_DC_01.1.14.2 | Ajuste de L&F | 16h? | 2006-07-17 10:00 | 2006-07-19 10:00 | 73 | 22.85d | 0d | GWT Analista 2 [80%] | 12.8h |
| 75 | GWT_DC_01.1.14.3 | Revisión de administración de cuenta del cliente | 8h? | 2006-07-19 10:00 | 2006-07-20 10:00 | 74 | 22.85d |  | GWT Lider Proyecto [80%] | 6.4h |
| 76 | GWT_DC_01.1.32.13 | **Libreta de contactos** | 4d? | 2006-07-14 10:00 | 2006-07-20 10:00 | 23 | 22.85d |  |  | 59.2h |
| 77 | GWT_DC_01.1.15.1 | Definición de L&F | 8h? | 2006-07-14 10:00 | 2006-07-17 10:00 |  | 22.85d | 0d | DC Diseñador | 8h |
| 78 | GWT_DC_01.1.15.2 | Ajustes de L&F | 24h? | 2006-07-17 10:00 | 2006-07-20 10:00 | 77 | 22.85d |  | GLP,GA2 | 24h |
| 79 | GWT_DC_01.1.15.3 | Detectar que un agregado a la libreta de contactos está registrado y permitir incluirlo en un grupo | 4h? | 2006-07-14 10:00 | 2006-07-14 15:00 |  | 26.35d |  | GWT Analista 2 [80%] | 3.2h |
| 80 | GWT_DC_01.1.15.4 | Invitar a dichis.com | 8h? | 2006-07-14 10:00 | 2006-07-17 10:00 |  | 25.85d |  | GLP,GP1 | 8h |
| 81 | GWT_DC_01.1.15.5 | Visualización, edición, creación y eliminación de un grupo (Detalle grupo) | 9.6h? | 2006-07-14 10:00 | 2006-07-17 11:36 |  | 24.85d | 0d | GA1,GA2 | 9.6h |
| 82 | GWT_DC_01.1.15.6 | Visualización, edición, creación y eliminación de Mis grupos | 6.4h? | 2006-07-17 11:36 | 2006-07-18 10:00 | 81 | 24.85d |  | GA1,GA2 | 6.4h |

| ID | WBS | Task | Duration | Start | Finish | Predecessors | Total slack | Free slack | Resources | Work |
| --- | --- | --- | --- | --- | --- | --- | --- | --- | --- | --- |
| 83 | GWT_DC_01.1.32.14 | **Proyectos** | 11.3d? | 2006-07-26 15:24 | 2006-08-11 08:48 | 68 | 0d |  |  | 299.2h |
| 84 | GWT_DC_01.1.16.1 | **Albumes** | 11.3d? | 2006-07-26 15:24 | 2006-08-11 08:48 |  | 0d |  |  | 168.8h |
| 85 | GWT_DC_01.1.16.1.1 | Reconsiderar L&F en Albumes | 36h? | 2006-07-26 15:24 | 2006-08-02 10:24 |  | 0d |  | GWT Lider Proyecto [80%] | 28.8h |
| 86 | GWT_DC_01.1.16.1.2 | Revisión de funcionalidad de Albumes | 24h | 2006-08-02 10:24 | 2006-08-07 10:24 | 85 | 0d |  | GWT Lider Proyecto [80%] | 19.2h |
| 87 | GWT_DC_01.1.16.1.3 | Revisión de proceso de construcción del album. Considerar que una foto al ser seleccionada no debe desincorporarse del carrusel sino que debe ser marcada, de modo tal que pueda utilizarse en múltiples ocasiones | 24h? | 2006-08-07 10:24 | 2006-08-10 10:24 | 86 | 0d |  | GWT Lider Proyecto [80%] | 19.2h |
| 88 | GWT_DC_01.1.16.1.4 | Pruebas de imprenta | 6.4h? | 2006-08-10 10:24 | 2006-08-11 08:48 | 87 | 0d |  | GLP,DLP,TLP | 6.4h |
| 89 | GWT_DC_01.1.16.1.5 | Consideraciones de estampillado de productos | 2h? | 2006-08-10 10:24 | 2006-08-10 13:24 | 87 | 0.55d |  | GWT Lider Proyecto [80%] | 1.6h |
| 90 | GWT_DC_01.1.16.1.6 | Información adicional a ser incluida en el PDF o txt. Ejemplo: carta al usuario, etiqueta para el sobre ,etc. | 2h? | 2006-08-10 10:24 | 2006-08-10 13:24 | 87 | 0.55d |  | GWT Lider Proyecto [80%] | 1.6h |
| 91 | GWT_DC_01.1.16.2 | **Postales** | 3.8d? | 2006-07-26 15:24 | 2006-08-01 13:48 |  | 7.5d |  |  | 28.8h |
| 92 | GWT_DC_01.1.16.2.1 | Reconsiderar L&F en Postales | 16h? | 2006-07-26 15:24 | 2006-07-28 15:24 |  | 7.5d | 0d | GWT Analista 1 [80%] | 12.8h |
| 93 | GWT_DC_01.1.16.2.2 | Revisión de funcionalidad de Postales | 8h? | 2006-07-28 15:24 | 2006-07-31 15:24 | 92 | 7.5d | 0d | GWT Analista 1 [80%] | 6.4h |
| 94 | GWT_DC_01.1.16.2.3 | Pruebas de imprenta | 6.4h? | 2006-07-31 15:24 | 2006-08-01 13:48 | 93 | 7.5d |  | GLP,DLP,TLP, | 6.4h |
| 95 | GWT_DC_01.1.16.2.4 | Consideraciones de estampillado de productos | 2h? | 2006-07-31 15:24 | 2006-08-01 08:24 | 93 | 8.05d |  | GWT Analista 1 [80%] | 1.6h |
| 96 | GWT_DC_01.1.16.2.5 | Información adicional a ser incluida en el PDF o txt. Ejemplo: carta al usuario, etiqueta para el sobre ,etc. | 2h? | 2006-07-31 15:24 | 2006-08-01 08:24 | 93 | 8.05d |  | GWT Analista 1 [80%] | 1.6h |
| 97 | GWT_DC_01.1.16.3 | **Regalos** | 3.8d? | 2006-07-26 15:24 | 2006-08-01 13:48 |  | 7.5d |  |  | 28.8h |
| 98 | GWT_DC_01.1.16.3.1 | Reconsiderar L&F en Regalos | 16h? | 2006-07-26 15:24 | 2006-07-28 15:24 |  | 7.5d | 0d | GWT Analista 2 [80%] | 12.8h |
| 99 | GWT_DC_01.1.16.3.2 | Revisión de funcionalidad de Regalos | 8h? | 2006-07-28 15:24 | 2006-07-31 15:24 | 98 | 7.5d | 0d | GWT Analista 2 [80%] | 6.4h |
| 100 | GWT_DC_01.1.16.3.3 | Pruebas de imprenta | 6.4h? | 2006-07-31 15:24 | 2006-08-01 13:48 | 99 | 7.5d |  | GA2,DLP,TLP | 6.4h |
| 101 | GWT_DC_01.1.16.3.4 | Consideraciones de estampillado de productos | 2h? | 2006-07-31 15:24 | 2006-08-01 08:24 | 99 | 8.05d |  | GWT Analista 2 [80%] | 1.6h |
| 102 | GWT_DC_01.1.16.3.5 | Información adicional a ser incluida en el PDF o txt. Ejemplo: carta al usuario, etiqueta para el sobre ,etc. | 2h? | 2006-07-31 15:24 | 2006-08-01 08:24 | 99 | 8.05d |  | GWT Analista 2 [80%] | 1.6h |
| 103 | GWT_DC_01.1.16.4 | **Gigantografías** | 8.85d? | 2006-07-26 15:24 | 2006-08-08 14:12 |  | 2.45d |  |  | 72.8h |
| 104 | GWT_DC_01.1.16.4.1 | Definición L&F | 8h? | 2006-07-26 15:24 | 2006-07-27 15:24 |  | 2.45d | 0d | DC Diseñador | 8h |
| 105 | GWT_DC_01.1.16.4.2 | **Construcción de programa de pasos para elaboración de las gigantografías** | 6.6d? | 2006-07-27 15:24 | 2006-08-07 11:12 | 104 | 2.45d | 0d |  | 52.8h |
| 106 | GWT_DC_01.1.16.4.2.1 | Pantalla de selección de material, medida y acabado | 12.8h? | 2006-07-27 15:24 | 2006-07-31 11:12 |  | 2.45d | 0d | GLP,GA1 | 12.8h |
| 107 | GWT_DC_01.1.16.4.2.2 | Pantalla de construcción de gigantografías a partir de templates | 40h? | 2006-07-31 11:12 | 2006-08-07 11:12 | 106 | 2.45d |  | GLP,GA1 | 40h |

| ID | WBS | Task | Duration | Start | Finish | Predecessors | Total slack | Free slack | Constraint | Resources | Work |
| --- | --- | --- | --- | --- | --- | --- | --- | --- | --- | --- | --- |
| 108 | GWT_DC_01.1.16.4.3 | **Construcción de PDF. Conexión con servidor de Mulá** | 0.25d? | 2006-08-07 11:12 | 2006-08-07 14:12 | 105 | 2.45d | 0d |  |  | 4h |
| 109 | GWT_DC_01.1.16.4.3.1 | Consideraciones de estampillado de productos | 2h? | 2006-08-07 11:12 | 2006-08-07 14:12 |  | 2.45d |  |  | GLP,GA2 | 2h |
| 110 | GWT_DC_01.1.16.4.3.2 | Información adicional a ser incluida en el PDF o txt. Ejemplo: carta al usuario, etiqueta para el sobre ,etc. | 2h? | 2006-08-07 11:12 | 2006-08-07 14:12 |  | 2.45d |  |  | GLP,GA2 | 2h |
| 111 | GWT_DC_01.1.16.4.4 | Pruebas de imprenta | 8h? | 2006-08-07 14:12 | 2006-08-08 14:12 | 108 | 2.45d |  |  | GLP,DLP,TLP | 8h |
| 112 | GWT_DC_01.1.32.15 | **Fotos sueltas (Quick shop)** | 3d? | 2006-07-21 08:00 | 2006-07-25 17:00 | 60 | 12.1d |  |  |  | 32h |
| 113 | GWT_DC_01.1.32.15.1 | Consideración de acabado mate y brillante | 8h? | 2006-07-21 08:00 | 2006-07-21 17:00 |  | 12.1d | 0d | start no earlier than 2006-07-19 08:00 | GA1,GA2 | 8h |
| 114 | GWT_DC_01.1.17.2 | Definición de L&F | 8h? | 2006-07-21 08:00 | 2006-07-21 17:00 |  | 12.1d | 0d |  | DC Diseñador | 8h |
| 115 | GWT_DC_01.1.17.3 | Ajuste de L&F | 16h? | 2006-07-24 08:00 | 2006-07-25 17:00 | 114, 113 | 12.1d |  |  | GA1,GA2 | 16h |
| 116 | GWT_DC_01.1.32.16 | **Colecciones de Partners** | 3.5d? | 2006-08-11 08:48 | 2006-08-16 13:48 | 83 | 3.5d |  |  |  | 27.2h |
| 117 | GWT_DC_01.1.18.2 | Definición de L&F | 8h? | 2006-08-11 08:48 | 2006-08-14 08:48 |  | 3.5d | 0d |  | DC Diseñador | 8h |
| 118 | GWT_DC_01.1.18.1 | **Galería de Foto Mulà (sin descarga de originales)** | 2d? | 2006-08-14 08:48 | 2006-08-16 08:48 | 117 | 3.5d | 0d |  |  | 16h |
| 119 | GWT_DC_01.1.18.1.1 | Visualización de Galería de Foto Mulà | 8h? | 2006-08-14 08:48 | 2006-08-15 08:48 |  | 3.5d | 0d |  | GLP,GA1 | 8h |
| 120 | GWT_DC_01.1.18.1.2 | Ajuste de programas para la selección de fotos para utilizar en productos | 8h? | 2006-08-15 08:48 | 2006-08-16 08:48 | 119 | 3.5d |  |  | GLP,GA2 | 8h |
| 121 | GWT_DC_01.1.18.3 | Ajuste de L&F | 4h? | 2006-08-16 08:48 | 2006-08-16 13:48 | 118 | 3.5d |  |  | GWT Analista 2 [80%] | 3.2h |
| 122 | GWT_DC_01.1.32.17 | **Carrito de compras** | 5d? | 2006-08-11 08:48 | 2006-08-18 08:48 | 83, 112 | 0d |  |  |  | 121.6h |
| 123 | GWT_DC_01.1.19.1 | Definición de L&F | 8h? | 2006-08-11 08:48 | 2006-08-14 08:48 |  | 0d |  |  | DC Diseñador | 8h |
| 124 | GWT_DC_01.1.19.2 | Ajuste de L&F | 32h? | 2006-08-14 08:48 | 2006-08-18 08:48 | 123 | 0d |  |  | GLP,GA2 | 32h |
| 125 | GWT_DC_01.1.19.3 | Precio de envío (consideraciones de aliados) | 8h? | 2006-08-11 08:48 | 2006-08-14 08:48 |  | 4d |  |  | GWT Lider Proyecto [80%] | 6.4h |
| 126 | GWT_DC_01.1.19.4 | Excentar de IVA a países de Latinoamerica | 8h? | 2006-08-11 08:48 | 2006-08-14 08:48 |  | 4d |  |  | GWT Lider Proyecto [80%] | 6.4h |
| 127 | GWT_DC_01.1.19.5 | Automatizar precio de Cuentas de Oro | 10h? | 2006-08-11 08:48 | 2006-08-14 10:48 |  | 3.75d |  |  | GWT Lider Proyecto [80%] | 8h |
| 128 | GWT_DC_01.1.19.6 | Precio de fotografías de Galería FotoMulà para distintos productos | 16h? | 2006-08-11 08:48 | 2006-08-15 08:48 |  | 3d |  |  | GLP,GA2 | 16h |
| 129 | GWT_DC_01.1.19.7 | **Manejar métodos de pago** | 3d? | 2006-08-11 08:48 | 2006-08-16 08:48 |  | 2d |  |  |  | 32h |
| 130 | GWT_DC_01.1.19.7.1 | Paypal (requiere investigación) | 24h? | 2006-08-11 08:48 | 2006-08-16 08:48 |  | 2d |  |  | GWT Analista 2 [80%] | 19.2h |
| 131 | GWT_DC_01.1.19.7.2 | Transferencia bancaria | 12h? | 2006-08-11 08:48 | 2006-08-14 13:48 |  | 3.5d |  |  | GWT Analista 2 [80%] | 9.6h |
| 132 | GWT_DC_01.1.19.7.3 | Tarjeta de crédito | 4h? | 2006-08-11 08:48 | 2006-08-11 13:48 |  | 4.5d |  |  | GWT Analista 2 [80%] | 3.2h |
| 133 | GWT_DC_01.1.19.8 | Manejo de precios en dólares y euros | 16h? | 2006-08-11 08:48 | 2006-08-15 08:48 |  | 3d |  |  | GWT Analista 2 [80%] | 12.8h |

Notes:
- 113: Depende de proveedor de servicio de impresion

| ID | WBS | Task | Duration | Start | Finish | Predecessors | Total slack | Free slack | Resources | Work |
| --- | --- | --- | --- | --- | --- | --- | --- | --- | --- | --- |
| 134 | GWT_DC_01.1.32.18 | **Reporte de Compras** | 2d? | 2006-08-18 08:48 | 2006-08-22 08:48 | 122 | 0d |  |  | 14.4h |
| 135 | GWT_DC_01.1.20.1 | Definición de L&F | 8h? | 2006-08-18 08:48 | 2006-08-21 08:48 |  | 0d |  | DC Diseñador | 8h |
| 136 | GWT_DC_01.1.20.2 | Ajuste de L&F | 8h? | 2006-08-21 08:48 | 2006-08-22 08:48 | 135 | 0d |  | GWT Analista 1 [80%] | 6.4h |
| 137 | GWT_DC_01.1.32.19 | **Selecciones** | 11.5d? | 2006-07-24 08:00 | 2006-08-08 12:00 | 52 | 3.6d | 0d |  | 206.8h |
| 138 | GWT_DC_01.1.21.1 | Definición de L&F | 8h? | 2006-07-24 08:00 | 2006-07-24 17:00 |  | 3.6d | 0d | DC Diseñador | 8h |
| 139 | GWT_DC_01.1.21.24 | Visualización de selecciones | 8h? | 2006-07-25 08:00 | 2006-07-25 17:00 | 138 | 3.6d | 0d | GWT Analista 1 [80%] | 6.4h |
| 140 | GWT_DC_01.1.21.16 | **Creación / edición de una selección** | 3d? | 2006-07-26 08:00 | 2006-07-28 17:00 | 139 | 3.6d | 0d |  | 44.8h |
| 141 | GWT_DC_01.1.21.16.1 | Escogencia y ordenamiento de fotos | 9.6h? | 2006-07-26 08:00 | 2006-07-27 09:36 |  | 5.4d |  | GA2,GA1 | 9.6h |
| 142 | GWT_DC_01.1.21.16.2 | Escogencia de portada y agregar descripción de la selección | 3.2h? | 2006-07-26 08:00 | 2006-07-26 11:12 |  | 6.2d |  | GA1,GA2 | 3.2h |
| 143 | GWT_DC_01.1.21.16.3 | Permitir la creación de la selección desde la vista de la foto -fotos en conjunto o detalle-, desde la carpeta, desde el home o desde upload. Considerar portada, descripción y ordenamiento. | 24h? | 2006-07-26 08:00 | 2006-07-28 17:00 |  | 3.6d |  | GA2,GA1 | 24h |
| 144 | GWT_DC_01.1.21.16.6 | Eliminación de la foto de la selección | 8h? | 2006-07-26 08:00 | 2006-07-26 17:00 |  | 5.6d |  | GA2,GA1 | 8h |
| 145 | GWT_DC_01.1.21.3 | **Visualización del detalle de una foto y edición de imágenes en una selección** | 3.5d? | 2006-07-31 08:00 | 2006-08-03 12:00 | 140 | 3.6d | 0d |  | 61.2h |
| 146 | GWT_DC_01.1.21.3.8 | Incorporación del carrusel de fotos | 12h? | 2006-07-31 08:00 | 2006-08-01 12:00 |  | 3.6d | 0d | GWT Analista 1 [80%] | 9.6h |
| 147 | GWT_DC_01.1.21.3.11 | Rotar | 16h? | 2006-08-01 13:00 | 2006-08-03 12:00 | 146 | 3.6d |  | GWT Analista 1 [80%] | 12.8h |
| 148 | GWT_DC_01.1.21.3.12 | Cambio de permisos: privada, pública, mis amigos, mis grupos | 8h? | 2006-08-01 13:00 | 2006-08-02 12:00 | 146 | 4.6d |  | GWT Analista 1 [80%] | 6.4h |
| 149 | GWT_DC_01.1.21.3.13 | Modificación del nombre, tags, Tooltip de la foto | 16h? | 2006-08-01 13:00 | 2006-08-03 12:00 | 146 | 3.6d |  | GWT Analista 1 [80%] | 12.8h |
| 150 | GWT_DC_01.1.21.3.19 | Descripción de la foto vinculada a la selección | 10h? | 2006-08-01 13:00 | 2006-08-02 15:00 | 146 | 4.35d |  | GWT Analista 1 [80%] | 8h |
| 151 | GWT_DC_01.1.21.3.15 | **Comentarios** | 1.81d? | 2006-07-31 08:00 | 2006-08-01 15:30 |  | 5.29d |  |  | 11.6h |
| 152 | GWT_DC_01.1.21.3.15.1 | Admisión de comentarios | 4h? | 2006-07-31 08:00 | 2006-07-31 12:00 |  | 5.29d | 0d | GWT Analista 1 [80%] | 3.2h |
| 153 | GWT_DC_01.1.32.19.3.15.5 | Opción para agregar comentarios | 8h? | 2006-07-31 13:00 | 2006-08-01 12:00 | 152 | 5.29d | 0d | GWT Analista 1 [80%] | 6.4h |
| 154 | GWT_DC_01.1.21.3.15.2 | Despliegue de comentarios | 2.5h? | 2006-08-01 13:00 | 2006-08-01 15:30 | 153 | 5.29d |  | GWT Analista 1 [80%] | 2h |
| 155 | GWT_DC_01.1.21.22 | **Visualización de grupo de Fotos** | 3d? | 2006-08-03 13:00 | 2006-08-08 12:00 | 145 | 3.6d |  |  | 73.6h |
| 156 | GWT_DC_01.1.21.22.20 | Tipo estándar: despliegue por páginas de 20 fotos cada una. | 24h? | 2006-08-03 13:00 | 2006-08-08 12:00 |  | 3.6d |  | GWT Analista 1 [80%] | 19.2h |
| 157 | GWT_DC_01.1.21.22.21 | Tipo Blog (ver en una sola pantalla todas las fotos con sus comentarios -cuando la foto es comentable-) | 8h? | 2006-08-03 13:00 | 2006-08-04 12:00 |  | 5.6d |  | GWT Analista 2 [80%] | 6.4h |
| 158 | GWT_DC_01.1.21.22.22 | Slideshow (investigación paquete existente) | 24h? | 2006-08-03 13:00 | 2006-08-08 12:00 |  | 3.6d |  | GA1,GA2 | 24h |

| ID | WBS | Task | Duration | Start | Finish | Predecessors | Total slack | Free slack | Resources | Work |
| --- | --- | --- | --- | --- | --- | --- | --- | --- | --- | --- |
| 159 | GWT_DC_01.1.21.23 | **Vigencias** | 1d? | 2006-07-31 08:00 | 2006-07-31 17:00 | 140 | 9.1d |  |  | 12.8h |
| 160 | GWT_DC_01.1.21.23.1 | Vigencia de la visualización de una foto en una selección | 8h? | 2006-07-31 08:00 | 2006-07-31 17:00 |  | 9.1d |  | GWT Analista 1 [80%] | 6.4h |
| 161 | GWT_DC_01.1.21.23.2 | Vigencia de la visualización de la selección | 8h? | 2006-07-31 08:00 | 2006-07-31 17:00 |  | 9.1d |  | GWT Analista 2 [80%] | 6.4h |
| 162 | GWT_DC_01.1.32.20 | **FotoBlog** | 3.5d? | 2006-08-08 13:00 | 2006-08-11 17:00 | 137 | 6.1d |  |  | 46.4h |
| 163 | GWT_DC_01.1.22.1 | Definición de L&F | 8h? | 2006-08-08 13:00 | 2006-08-09 12:00 |  | 6.1d | 0d | DC Diseñador | 8h |
| 164 | GWT_DC_01.1.22.5 | **Mecanismo de censura de fotos** | 2d? | 2006-08-09 13:00 | 2006-08-11 12:00 | 163 | 6.6d |  |  | 16h |
| 165 | GWT_DC_01.1.22.5.5 | Facilidad para permitir a un cliente marcar/desmarcar una foto como ofensiva | 8h? | 2006-08-09 13:00 | 2006-08-10 12:00 |  | 6.6d | 0d | GLP,GA2 | 8h |
| 166 | GWT_DC_01.1.22.5.6 | Reconocimiento de foto como ofensiva para el cliente | 8h? | 2006-08-10 13:00 | 2006-08-11 12:00 | 165 | 6.6d |  | GLP,GA2 | 8h |
| 167 | GWT_DC_01.1.22.6 | Slideshow (link) | 4h? | 2006-08-09 13:00 | 2006-08-09 17:00 | 163 | 8.1d |  | GWT Lider Proyecto [80%] | 3.2h |
| 168 | GWT_DC_01.1.22.7 | Acceso a través de URL al estilo www.dichis.com/login_cliente | 16h? | 2006-08-09 13:00 | 2006-08-11 12:00 | 163 | 6.1d | 0d | GA1,GO1 | 16h |
| 169 | GWT_DC_01.1.22.8 | Pantalla de despliegue de selecciones con fotos blogueables | 4h? | 2006-08-11 13:00 | 2006-08-11 17:00 | 168 | 6.1d |  | GWT Analista 2 [80%] | 3.2h |
| 170 | GWT_DC_01.1.32.21 | **Compartir: Selecciones** | 6d? | 2006-08-08 13:00 | 2006-08-16 12:00 | 137 | 3.6d |  |  | 56h |
| 171 | GWT_DC_01.1.23.1 | Definición de L&F | 8h? | 2006-08-08 13:00 | 2006-08-09 12:00 |  | 3.6d | 0d | DC Diseñador | 8h |
| 172 | GWT_DC_01.1.23.2 | Mecanismo para compartir selecciones a imagen y semejanza de compartir de carpetas en PHS. | 16h? | 2006-08-09 13:00 | 2006-08-11 12:00 | 171 | 3.6d | 0d | GLP,GA1 | 16h |
| 173 | GWT_DC_01.1.32.21.7 | Visualización de selecciones que he compartido. Filtros: compartidas por contactos, públicas, privadas. | 24h? | 2006-08-11 13:00 | 2006-08-16 12:00 | 172 | 3.6d |  | GWT Lider Proyecto [80%] | 19.2h |
| 174 | GWT_DC_01.1.23.4 | Incluir invitación a contacto no registrado cuando se comparte | 4h? | 2006-08-11 13:00 | 2006-08-11 17:00 | 172 | 6.1d |  | GWT Lider Proyecto [80%] | 3.2h |
| 175 | GWT_DC_01.1.23.5 | **Notificación de cambios en blogs compartidos** | 1d? | 2006-08-11 13:00 | 2006-08-14 12:00 | 171, 172 | 5.6d |  |  | 9.6h |
| 176 | GWT_DC_01.1.23.5.1 | Almacenar fecha de modificación de blog. | 4h? | 2006-08-11 13:00 | 2006-08-11 17:00 |  | 5.6d | 0d | GWT Analista 2 [80%] | 3.2h |
| 177 | GWT_DC_01.1.23.5.2 | Almacenar fecha de última visita de un contacto al blog. Estudiar mecanismo | 4h? | 2006-08-11 13:00 | 2006-08-11 17:00 |  | 5.6d | 0d | GWT Analista 2 [80%] | 3.2h |
| 178 | GWT_DC_01.1.23.5.3 | Indicación de modificación de un blog desde la última visita | 4h? | 2006-08-14 08:00 | 2006-08-14 12:00 | 176, 177 | 5.6d |  | GWT Analista 1 [80%] | 3.2h |
| 179 | GWT_DC_01.1.32.22 | Compartir: Proyectos Revisar mecanismo actual | 1d? | 2006-08-11 08:48 | 2006-08-14 08:48 | 83 | 6d |  | GWT Lider Proyecto [80%] | 6.4h |
| 180 | GWT_DC_01.1.32.23 | **Búsqueda de fotos** | 1d? | 2006-08-08 13:00 | 2006-08-09 12:00 | 137 | 8.6d |  |  | 12.8h |
| 181 | GWT_DC_01.1.25.1 | Búsqueda de fotos por tag en la cabecera de Mi Dichis | 8h? | 2006-08-08 13:00 | 2006-08-09 12:00 |  | 8.6d |  | GWT Analista 1 [80%] | 6.4h |
| 182 | GWT_DC_01.1.25.2 | Búsqueda avanzada utilizando: fecha, usuario, palabras clave, descripción, tamaños, tipo, resolución, precio, metadata. | 8h? | 2006-08-08 13:00 | 2006-08-09 12:00 |  | 8.6d |  | GWT Analista 1 [80%] | 6.4h |
| 183 | GWT_DC_01.1.32.24 | Ampliación de estadísticas (BO) Productos por categorías por partner | 0.5d? | 2006-08-18 08:48 | 2006-08-18 13:48 | 122 | 1.5d |  | GWT Analista 2 [80%] | 3.2h |

Notes:
- 183: Ampliación de PHS (ya estará implementado en PHS)

| ID | WBS | Task | Duration | Start | Finish | Predecessors | Total slack | Resources | Work |
| --- | --- | --- | --- | --- | --- | --- | --- | --- | --- |
| 184 | GWT_DC_01.1.32.25 | **Enlatados** | 1.5d? | 2006-07-14 10:00 | 2006-07-17 15:00 | 23 | 25.35d |  | 20h |
| 185 | GWT_DC_01.1.27.2 | Revisión de envío de correos automáticos | 8h? | 2006-07-14 10:00 | 2006-07-17 10:00 |  | 25.85d | GLP,TLP,DLP | 8h |
| 186 | GWT_DC_01.1.27.1 | Definición de correos (enlatados) _idi | 12h? | 2006-07-14 10:00 | 2006-07-17 15:00 |  | 25.35d | TLP,DLP | 12h |
| 187 | GWT_DC_01.1.35 | **Implantación** | 13d? | 2006-08-22 08:48 | 2006-09-08 08:48 | 17 | 0d |  | 109.6h |
| 188 | GWT_DC_01.1.35.7 | Entrenamiento al usuario | 8h? | 2006-08-22 08:48 | 2006-08-23 08:48 |  | 0d | TN Lider Proyecto [70%] | 5.6h |
| 189 | GWT_DC_01.1.35.2 | Definición de templates para puesta al aire | 16h? | 2006-08-23 08:48 | 2006-08-25 08:48 | 188 | 0d | TLP,DLP | 16h |
| 190 | GWT_DC_01.1.35.4 | Migración a ambiente de producción | 8h? | 2006-08-22 08:48 | 2006-08-23 08:48 |  | 2d | GLP,GA1,GA2,GO1 | 8h |
| 191 | GWT_DC_01.1.35.5 | Pruebas en ambiente de producción | 40h? | 2006-08-25 08:48 | 2006-09-01 08:48 | 189, 190 | 0d | GLP,GA1,GA2 | 40h |
| 192 | GWT_DC_01.1.35.6 | Ajustes tras pruebas en producción | 40h? | 2006-09-01 08:48 | 2006-09-08 08:48 | 191 | 0d | GLP,GA1,GA2 | 40h |
| 193 | GWT_DC_01.1.36 | **Documentación** | 6.25d? | 2006-09-08 08:48 | 2006-09-18 10:48 | 187 | 0d |  | 80h |
| 194 | GWT_DC_01.1.36.2 | Manual de usuario | 30h | 2006-09-08 08:48 | 2006-09-13 15:48 |  | 2.5d | TLP,DLP | 30h |
| 195 | GWT_DC_01.1.36.3 | Documentación técnica | 50h? | 2006-09-08 08:48 | 2006-09-18 10:48 |  | 0d | GLP,GA1,GA2 | 50h |

Notes:
- 185: Un documento (.doc) que dice que corres existen
