# Plan PRs

Schedule from MS Project, 2006-09-05 to 2006-11-15, A marks actual dates.
GWT

## Calendars

- Standard: Mon-Fri 08:00-12:00, 13:00-17:00; Sat-Sun off. Exceptions (off unless hours are given): 2006-10-12.

## Resources

| Resource |
| --- |
| Gustavo |
| Kathy |
| Listbeth |
| Mila |
| Listbeth(10%) |
| Beta |

## Schedule

| ID | WBS | Task | Duration | Start | Finish | Predecessors | Complete | Remaining | Total slack | Constraint | Resources | Work | Actual work |
| --- | --- | --- | --- | --- | --- | --- | --- | --- | --- | --- | --- | --- | --- |
| 1 | 1 | **Foto XS - PR´s** | 50.5d | 2006-09-05 08:00 A | 2006-11-15 12:00 |  | 45% | 27.58d | 0d |  |  | 388h | 167.6h |
| 2 | 1.1 | **Configuración y Desarrollo** | 45.5d | 2006-09-05 08:00 A | 2006-11-08 12:00 |  | 74% | 11.94d | 0d |  |  | 288h | 167.6h |
| 3 | 1.1.1 | PR 329 | 0.25d | 2006-09-05 08:00 A | 2006-09-05 10:00 A |  | 100% |  |  | start no earlier than 2006-09-05 08:00 | Gustavo | 2h | 2h |
| 4 | 1.1.2 | PR 87 | 0.25d | 2006-09-05 08:00 A | 2006-09-05 10:00 A |  | 100% |  |  | start no earlier than 2006-09-05 08:00 | Gustavo | 2h | 2h |
| 5 | 1.1.3 | PR 259 | 0.25d | 2006-09-05 08:00 A | 2006-09-05 10:00 A |  | 100% |  |  | start no earlier than 2006-09-05 08:00 | Gustavo | 2h | 2h |
| 6 | 1.1.4 | PR 276 | 0.25d | 2006-09-05 08:00 A | 2006-09-05 10:00 A |  | 100% |  |  | start no earlier than 2006-09-05 08:00 | Gustavo | 2h | 2h |
| 7 | 1.1.5 | PR 304 | 0.25d | 2006-09-06 08:00 A | 2006-09-06 10:00 A |  | 100% |  |  | start no earlier than 2006-09-06 08:00 | Gustavo | 2h | 2h |
| 8 | 1.1.6 | PR 337 | 0.5d | 2006-09-06 08:00 A | 2006-09-06 12:00 A |  | 100% |  |  | start no earlier than 2006-09-06 08:00 | Gustavo | 4h | 4h |
| 9 | 1.1.7 | PR 256 | 0.5d | 2006-09-06 08:00 A | 2006-09-06 12:00 A |  | 100% |  |  | start no earlier than 2006-09-06 08:00 | Gustavo | 4h | 4h |
| 10 | 1.1.8 | PR 22 | 0.25d | 2006-09-07 08:00 A | 2006-09-07 10:00 A |  | 100% |  |  | start no earlier than 2006-09-07 08:00 | Gustavo | 2h | 2h |
| 11 | 1.1.9 | PR 59 | 0.25d | 2006-09-07 08:00 A | 2006-09-07 10:00 A |  | 100% |  |  | start no earlier than 2006-09-07 08:00 | Gustavo | 2h | 2h |
| 12 | 1.1.10 | PR 5 | 0.25d | 2006-09-07 08:00 A | 2006-09-07 10:00 A |  | 100% |  |  | start no earlier than 2006-09-07 08:00 | Gustavo | 2h | 2h |
| 13 | 1.1.11 | PR 278 | 1d | 2006-09-08 08:00 A | 2006-09-08 17:00 A |  | 100% |  |  | start no earlier than 2006-09-08 08:00 | Gustavo | 8h | 8h |
| 14 | 1.1.12 | PR 240 | 0.5d | 2006-09-11 08:00 A | 2006-09-11 12:00 A |  | 100% |  |  | start no earlier than 2006-09-11 08:00 | Gustavo | 4h | 4h |
| 15 | 1.1.13 | PR 258 | 0.5d | 2006-09-11 08:00 A | 2006-09-11 12:00 A |  | 100% |  |  | start no earlier than 2006-09-11 08:00 | Gustavo | 4h | 4h |
| 16 | 1.1.14 | PR 268 | 0.75d | 2006-09-13 08:00 A | 2006-09-13 15:00 A |  | 100% |  |  | start no earlier than 2006-09-13 08:00 | Gustavo | 6h | 6h |
| 17 | 1.1.15 | PR 7 | 0.5d | 2006-09-14 08:00 A | 2006-09-14 12:00 A |  | 100% |  |  | start no earlier than 2006-09-14 08:00 | Gustavo | 4h | 4h |
| 18 | 1.1.16 | PR 89 | 0.5d | 2006-09-15 08:00 A | 2006-09-15 12:00 A |  | 100% |  |  | start no earlier than 2006-09-15 08:00 | Gustavo | 4h | 4h |
| 19 | 1.1.17 | PR 17 | 0.75d | 2006-09-18 08:00 A | 2006-09-18 15:00 A |  | 100% |  |  | start no earlier than 2006-09-18 08:00 | Gustavo | 6h | 6h |
| 20 | 1.1.18 | PR 372 | 8d | 2006-09-18 08:00 A | 2006-09-27 17:00 A |  | 100% |  |  | start no earlier than 2006-09-18 08:00 | Gustavo [25%] | 16h | 16h |
| 21 | 1.1.19 | PR 94 | 0.25d | 2006-09-19 08:00 A | 2006-09-19 10:00 A |  | 100% |  |  | start no earlier than 2006-09-19 08:00 | Gustavo | 2h | 2h |
| 22 | 1.1.20 | PR 280 | 0.25d | 2006-09-20 08:00 A | 2006-09-20 10:00 A |  | 100% |  |  | start no earlier than 2006-09-20 08:00 | Gustavo | 2h | 2h |
| 23 | 1.1.21 | PR 96 | 0.25d | 2006-09-20 08:00 A | 2006-09-20 10:00 A |  | 100% |  |  | start no earlier than 2006-09-20 08:00 | Gustavo; Mila | 4h | 4h |
| 24 | 1.1.22 | PR 103 | 1.5d | 2006-09-21 08:00 A | 2006-09-22 12:00 A |  | 100% |  |  | start no earlier than 2006-09-21 08:00 | Gustavo | 12h | 12h |
| 25 | 1.1.23 | PR 10 | 0.5d | 2006-09-22 08:00 A | 2006-09-22 12:00 A |  | 100% |  |  | start no earlier than 2006-09-22 08:00 |  | 4h | 4h |
| 26 | 1.1.24 | PR 193 | 0.25d | 2006-09-26 08:00 A | 2006-09-26 10:00 A |  | 100% |  |  | start no earlier than 2006-09-26 08:00 | Gustavo | 2h | 2h |
| 27 | 1.1.25 | PR 117 | 2d | 2006-10-09 08:00 A | 2006-10-10 17:00 A |  | 100% |  |  | start no earlier than 2006-10-09 08:00 | Gustavo [50%] | 8h | 8h |
| 28 | 1.1.26 | PR 273 | 1d | 2006-10-11 08:00 A | 2006-10-11 17:00 A | 27 | 100% |  |  |  | Gustavo | 8h | 8h |
| 29 | 1.1.27 | PR 102 | 1d | 2006-10-17 08:00 A | 2006-10-17 17:00 A | 28 | 100% |  |  |  | Gustavo | 8h | 8h |
| 30 | 1.1.28 | PR 93 | 1d | 2006-10-25 08:00 A | 2006-10-25 17:00 A | 29 | 100% |  |  |  | Gustavo | 8h | 8h |
| 31 | 1.1.29 | PR 185 | 1d | 2006-10-18 08:00 A | 2006-10-18 17:00 A | 30 | 100% |  |  |  | Gustavo | 8h | 8h |
| 32 | 1.1.30 | PR 14 | 1d | 2006-10-19 08:00 A | 2006-10-19 17:00 A | 31 | 100% |  |  |  | Gustavo | 8h | 8h |
| 33 | 1.1.31 | PR 21 | 1d | 2006-11-01 08:00 A | 2006-11-01 17:00 A | 32 | 100% |  |  |  | Gustavo | 8h | 8h |
| 34 | 1.1.32 | PR 170 | 1d | 2006-10-24 08:00 A | 2006-10-24 17:00 A | 33 | 100% |  |  |  | Gustavo | 8h | 8h |
| 35 | 1.1.33 | PR 241 | 2.5d | 2006-09-19 08:00 A | 2006-10-25 12:00 | 34 | 80% | 0.5d | 0d | start no earlier than 2006-09-19 08:00 | Gustavo [10%] | 2h | 1.6h |
| 36 | 1.1.34 | PR 261 | 1d | 2006-10-25 13:00 | 2006-10-26 12:00 | 35 |  |  | 0d |  | Gustavo | 8h |  |
| 37 | 1.1.35 | PR 18 | 1d | 2006-10-26 13:00 | 2006-10-27 12:00 | 36 |  |  | 0d |  | Gustavo | 8h |  |
| 38 | 1.1.36 | PR 3 | 5d | 2006-10-27 13:00 | 2006-11-03 12:00 | 37 |  |  | 0d | start no earlier than 2006-09-29 08:00 | Gustavo; Beta | 80h |  |
| 39 | 1.1.37 | PR 106 | 0.5d | 2006-11-03 13:00 | 2006-11-03 17:00 | 38 |  |  | 0d |  | Gustavo | 4h |  |
| 40 | 1.1.38 | PR 90 | 0.5d | 2006-11-06 08:00 | 2006-11-06 12:00 | 39 |  |  | 0d |  | Gustavo | 4h |  |
| 41 | 1.1.39 | PR 98 | 1d | 2006-11-06 13:00 | 2006-11-07 12:00 | 40 |  |  | 0d |  | Gustavo | 8h |  |
| 42 | 1.1.40 | PR 8 | 1d | 2006-11-07 13:00 | 2006-11-08 12:00 | 41 |  |  | 0d |  | Gustavo | 8h |  |
| 43 | 1.2 | Ajustes recomendados | 5d | 2006-11-08 13:00 | 2006-11-15 12:00 | 2 |  |  | 0d |  | Gustavo | 40h |  |

Notes:
- 23: Espera de Material

| ID | WBS | Task | Duration | Start | Finish | Total slack | Constraint | Resources | Work |
| --- | --- | --- | --- | --- | --- | --- | --- | --- | --- |
| 44 | 1.3 | **Gerencia de Proyecto** | 45d | 2006-09-11 08:00 | 2006-11-13 17:00 | 1.5d |  |  | 60h |
| 45 | 1.3.1 | Planificación | 15d | 2006-09-12 08:00 | 2006-10-02 17:00 | 30.5d | start no earlier than 2006-09-12 08:00 | Listbeth [10%] | 12h |
| 46 | 1.3.2 | **Control y Seguimiento** | 34.5d | 2006-09-11 08:00 | 2006-10-30 12:00 | 12d |  |  | 24h |
| 47 | 1.3.2.1 | 11-09 | 0.5d | 2006-09-11 08:00 | 2006-09-11 12:00 | 46d | start no earlier than 2006-09-11 08:00 | Gustavo [25%]; Kathy [25%]; Listbeth [25%] | 3h |
| 48 | 1.3.2.2 | 18-09 | 0.5d | 2006-09-18 08:00 | 2006-09-18 12:00 | 41d | start no earlier than 2006-09-18 08:00 | Gustavo [25%]; Kathy [25%]; Listbeth [25%] | 3h |
| 49 | 1.3.2.3 | 25-09 | 0.5d | 2006-09-25 08:00 | 2006-09-25 12:00 | 36d | start no earlier than 2006-09-25 08:00 | Gustavo [25%]; Kathy [25%]; Listbeth [25%] | 3h |
| 50 | 1.3.2.4 | 02-10 | 0.5d | 2006-10-02 08:00 | 2006-10-02 12:00 | 31d | start no earlier than 2006-10-02 08:00 | Gustavo [25%]; Kathy [25%]; Listbeth [25%] | 3h |
| 51 | 1.3.2.5 | 09-10 | 0.5d | 2006-10-09 08:00 | 2006-10-09 12:00 | 26d | start no earlier than 2006-10-09 08:00 | Gustavo [25%]; Kathy [25%]; Listbeth [25%] | 3h |
| 52 | 1.3.2.6 | 16-10 | 0.5d | 2006-10-16 08:00 | 2006-10-16 12:00 | 22d | start no earlier than 2006-10-16 08:00 | Gustavo [25%]; Kathy [25%]; Listbeth [25%] | 3h |
| 53 | 1.3.2.7 | 23-10 | 0.5d | 2006-10-23 08:00 | 2006-10-23 12:00 | 17d | start no earlier than 2006-10-23 08:00 | Gustavo [25%]; Kathy [25%]; Listbeth [25%] | 3h |
| 54 | 1.3.2.8 | 30-10 | 0.5d | 2006-10-30 08:00 | 2006-10-30 12:00 | 12d | start no earlier than 2006-10-30 08:00 | Gustavo [25%]; Kathy [25%]; Listbeth [25%] | 3h |
| 55 | 1.3.3 | Cierre | 1d | 2006-11-13 08:00 | 2006-11-13 17:00 | 1.5d | start no earlier than 2006-11-13 08:00 | Gustavo; Kathy; Listbeth | 24h |
