# Seventec Propuesta

Schedule from MS Project, 2006-10-16 to 2007-04-27, costs in Bs.
GlobalWebTek

## Calendars

- Standard: Mon-Fri 08:00-12:00, 13:00-17:00; Sat-Sun off. Exceptions (off unless hours are given): 2006-12-25, 2007-01-01, 2007-04-19.

## Resources

| Resource | Rate |
| --- | --- |
| MR | 15000 |
| EC | 6250 |
| DS | 6250 |
| LR |  |
| AL | 15000 |

## Schedule

| ID | WBS | Task | Type | Duration | Start | Finish | Predecessors | Total slack | Free slack | Constraint | Resources | Work | Cost |
| --- | --- | --- | --- | --- | --- | --- | --- | --- | --- | --- | --- | --- | --- |
| 1 | 1 | **Control de Servicios de Infraestructura** |  | 135.5d | 2006-10-16 | 2007-04-27 |  | 0d |  |  |  | 1502h | 13,565,000 |
| 2 | 1.1 | **Inicio** |  | 0.25d | 2006-10-18 | 2006-10-18 |  | 134.1d |  |  |  | 4h | 30,000 |
| 3 | 1.1.1 | Reunión de Kickoff |  | 2h | 2006-10-18 | 2006-10-18 |  | 134.1d |  | start no earlier than 2006-10-18 | LR; MR | 4h | 30,000 |
| 4 | 1.2 | **Levantamiento de Información General** |  | 0.5d | 2006-10-23 | 2006-10-23 |  | 0d |  |  |  | 4h | 60,000 |
| 5 | 1.2.1 | Sesión de Trabajo única (General de las tres Fases) |  | 4h | 2006-10-23 | 2006-10-23 |  | 0d |  | start no earlier than 2006-10-23 | MR | 4h | 60,000 |
| 6 | 1.3 | **FASE I** |  | 69.67d | 2006-10-23 | 2007-01-31 |  | 0d |  |  |  | 566h | 5,235,000 |
| 7 | 1.3.1 | **Levantamiento de Información** |  | 6.5d | 2006-10-25 | 2006-11-02 |  | 61.67d |  |  |  | 20h | 300,000 |
| 8 | 1.3.1.1 | Sesión de Trabajo 1 |  | 8h | 2006-10-25 | 2006-10-25 |  | 67.17d |  | start no earlier than 2006-10-25 | MR | 8h | 120,000 |
| 9 | 1.3.1.2 | Sesión de Trabajo 2 |  | 8h | 2006-10-31 | 2006-10-31 |  | 60.17d | 0d | start no earlier than 2006-10-31 | MR | 8h | 120,000 |
| 10 | 1.3.1.3 | Sesión de Trabajo 3 |  | 4h | 2006-11-02 | 2006-11-02 |  | 61.67d |  | start no earlier than 2006-11-02 | MR | 4h | 60,000 |
| 11 | 1.3.2 | **Requerimientos, Análisis y Diseño** |  | 12d | 2006-10-31 | 2006-11-15 |  | 8.92d | 0d |  |  | 60h | 900,000 |
| 12 | 1.3.2.1 | Documento de Especificación de Requerimientos |  | 3d | 2006-11-01 | 2006-11-03 | 9 | 60.17d |  | finish no earlier than 2006-11-03 | MR | 24h | 360,000 |
| 13 | 1.3.2.2 | Ajustes Documento de Especificaciones |  | 8h | 2006-11-10 | 2006-11-10 |  | 0.92d | 0d | start no earlier than 2006-11-10 | MR | 8h | 120,000 |
| 14 | 1.3.2.3 | Análisis y Diseño |  | 3d | 2006-11-13 | 2006-11-15 | 13 | 0.92d | 0d |  | MR | 24h | 360,000 |
| 15 | 1.3.2.4 | Creación de Aplicación en N2C |  | 4h | 2006-10-31 | 2006-10-31 |  | 63.67d |  | start no earlier than 2006-10-31 | AL | 4h | 60,000 |
| 16 | 1.3.3 | **Construcción** |  | 47.25d | 2006-11-16 | 2007-01-24 |  | 0.92d |  |  |  | 438h | 3,315,000 |
| 17 | 1.3.3.1 | **Prototipo** |  | 7.25d | 2006-11-16 | 2006-11-27 |  | 0.92d | 0d |  |  | 114h | 730,000 |
| 18 | 1.3.3.1.1 | Desarrollo |  | 5d | 2006-11-16 | 2006-11-22 | 14 | 0.92d | 0d |  | EC; DS | 80h | 500,000 |
| 19 | 1.3.3.1.2 | Presentación |  | 2h | 2006-11-23 | 2006-11-23 | 18 | 0.92d | 0d |  | MR | 2h | 30,000 |
| 20 | 1.3.3.1.3 | Ajustes |  | 2d | 2006-11-23 | 2006-11-27 | 19 | 0.92d |  |  | EC; DS | 32h | 200,000 |
| 21 | 1.3.3.2 | Prototipo Fase I | milestone | 0d | 2006-11-27 | 2006-11-27 | 17 | 44.92d |  |  |  |  |  |
| 22 | 1.3.3.3 | **Construcción Funcionalidades** |  | 40d | 2006-11-27 | 2007-01-24 |  | 0.92d |  |  |  | 324h | 2,585,000 |
| 23 | 1.3.3.3.1 | Módulo de Directorio de Clientes |  | 6d | 2006-11-27 | 2006-12-05 | 17 | 0.92d | 0d |  | DS [50%] | 24h | 150,000 |
| 24 | 1.3.3.3.2 | Módulo de Gestión de Servicios |  | 16.5d | 2006-11-27 | 2006-12-19 | 17 | 28.42d |  |  | EC | 132h | 825,000 |
| 25 | 1.3.3.3.3 | Módulo de Administración de Usuarios |  | 6d | 2006-12-05 | 2006-12-13 | 23 | 0.92d | 0d |  | DS [50%] | 24h | 150,000 |
| 26 | 1.3.3.3.4 | Pruebas Internas y Ajustes |  | 25d | 2006-12-13 | 2007-01-19 | 25 | 0.92d | 0d | finish no earlier than 2007-01-15 | MR; EC [20%]; DS [50%] | 120h | 1,100,000 |
| 27 | 1.3.3.3.5 | Guías de Usuario |  | 3d | 2007-01-19 | 2007-01-24 | 26 | 0.92d | 0d |  | MR | 24h | 360,000 |
| 28 | 1.3.4 | Pruebas de Certificación |  | 1.5d | 2007-01-24 | 2007-01-25 | 27 | 0.92d | 0d |  | MR | 12h | 180,000 |

| ID | WBS | Task | Type | Duration | Start | Finish | Predecessors | Total slack | Free slack | Constraint | Resources | Work | Cost |
| --- | --- | --- | --- | --- | --- | --- | --- | --- | --- | --- | --- | --- | --- |
| 29 | 1.3.5 | **Puesta en Marcha** |  | 2.5d | 2007-01-25 | 2007-01-30 |  | 0.92d | 0d |  |  | 20h | 300,000 |
| 30 | 1.3.5.1 | Adiestramiento Módulo Dir de Clientes |  | 4h | 2007-01-25 | 2007-01-26 | 28 | 0.92d | 0d |  | MR | 4h | 60,000 |
| 31 | 1.3.5.2 | Adiestramiento Gestión de Servicios |  | 4h | 2007-01-26 | 2007-01-26 | 30 | 0.92d | 0d |  | MR | 4h | 60,000 |
| 32 | 1.3.5.3 | Adiestramiento Adm Usuarios |  | 4h | 2007-01-26 | 2007-01-29 | 31 | 0.92d | 0d |  | MR | 4h | 60,000 |
| 33 | 1.3.5.4 | Implantación Fase I |  | 1d | 2007-01-29 | 2007-01-30 | 32 | 0.92d |  |  | AL | 8h | 120,000 |
| 34 | 1.3.6 | Seguimiento Fase I |  | 533.33h | 2006-10-23 | 2007-01-31 | 5 | 0d |  | finish no earlier than 2007-01-24 | MR [3%] | 16h | 240,000 |
| 35 | 1.3.7 | Módulos Fase I | milestone | 0d | 2007-01-30 | 2007-01-30 | 29 | 0.75d |  |  |  |  |  |
| 36 | 1.4 | **FASE II** |  | 43.17d | 2007-01-29 | 2007-03-29 |  | 2.17d |  |  |  | 551h | 5,115,000 |
| 37 | 1.4.1 | **Levantamiento de Información** |  | 2.67d | 2007-01-29 | 2007-01-31 |  | 0d |  |  |  | 12h | 180,000 |
| 38 | 1.4.1.1 | Sesión de Trabajo 1 |  | 4h | 2007-01-31 | 2007-01-31 | 6 | 0d |  | start no earlier than 2007-01-04 | MR | 4h | 60,000 |
| 39 | 1.4.1.2 | Sesión de Trabajo 2 |  | 4h | 2007-01-29 | 2007-01-29 |  | 2.17d |  | start no earlier than 2007-01-29 | MR | 4h | 60,000 |
| 40 | 1.4.1.3 | Sesión de Trabajo 3 |  | 4h | 2007-01-31 | 2007-01-31 |  | 0.17d |  | start no earlier than 2007-01-31 | MR | 4h | 60,000 |
| 41 | 1.4.2 | **Requerimientos, Análisis y Diseño** |  | 8d | 2007-01-31 | 2007-02-12 |  | 0d |  |  |  | 64h | 960,000 |
| 42 | 1.4.2.1 | Documento de Especificación de Requerimientos |  | 2d | 2007-01-31 | 2007-02-02 | 37 | 0d |  |  | MR | 16h | 240,000 |
| 43 | 1.4.2.2 | Ajustes Documento de Especificaciones |  | 1d | 2007-02-02 | 2007-02-05 | 42 | 0d |  |  | MR | 8h | 120,000 |
| 44 | 1.4.2.3 | Análisis y Diseño |  | 5d | 2007-02-05 | 2007-02-12 | 43 | 0d |  |  | MR | 40h | 600,000 |
| 45 | 1.4.3 | **Construcción** |  | 29d | 2007-02-12 | 2007-03-23 |  | 0d |  |  |  | 432h | 3,330,000 |
| 46 | 1.4.3.1 | Módulo de Control de Tiempos |  | 4d | 2007-02-12 | 2007-02-16 | 41 | 0d |  |  | DS [50%] | 16h | 100,000 |
| 47 | 1.4.3.2 | Módulo de Gestión de Inventario |  | 16d | 2007-02-16 | 2007-03-12 | 46 | 0d |  |  | DS [50%] | 64h | 400,000 |
| 48 | 1.4.3.3 | Módulo de Gestión de Recursos Humanos |  | 15d | 2007-02-12 | 2007-03-05 | 41 | 27.69d | 0d |  | EC | 120h | 750,000 |
| 49 | 1.4.3.4 | Módulo de Gestión de Materiales |  | 10d | 2007-03-05 | 2007-03-19 | 48 | 27.69d |  |  | EC | 80h | 500,000 |
| 50 | 1.4.3.5 | Pruebas Internas y Ajustes |  | 5d | 2007-03-12 | 2007-03-19 | 47 | 0d |  |  | MR; EC; DS | 120h | 1,100,000 |
| 51 | 1.4.3.6 | Guías de Usuario |  | 4d | 2007-03-19 | 2007-03-23 | 50 | 0d |  |  | MR | 32h | 480,000 |
| 52 | 1.4.4 | Pruebas de Certificación |  | 1d | 2007-03-23 | 2007-03-26 | 51 | 0d |  |  | MR | 8h | 120,000 |

| ID | WBS | Task | Type | Duration | Start | Finish | Predecessors | Total slack | Free slack | Constraint | Resources | Work | Cost |
| --- | --- | --- | --- | --- | --- | --- | --- | --- | --- | --- | --- | --- | --- |
| 53 | 1.4.5 | **Puesta en Marcha** |  | 2.5d | 2007-03-26 | 2007-03-29 |  | 0d |  |  |  | 20h | 300,000 |
| 54 | 1.4.5.1 | Adiestramiento Módulo Control de Tiempos |  | 4h | 2007-03-26 | 2007-03-27 | 52 | 0d |  |  | MR | 4h | 60,000 |
| 55 | 1.4.5.2 | Adiestramiento Inventario |  | 4h | 2007-03-27 | 2007-03-27 | 54 | 0d |  |  | MR | 4h | 60,000 |
| 56 | 1.4.5.3 | Adiestramiento Gestión RRHH |  | 4h | 2007-03-27 | 2007-03-28 | 55 | 0d |  |  | MR | 4h | 60,000 |
| 57 | 1.4.5.4 | Adiestramiento Materiales |  | 4h | 2007-03-28 | 2007-03-28 | 56 | 0d |  |  | MR | 4h | 60,000 |
| 58 | 1.4.5.5 | Implantación Fase II |  | 4h | 2007-03-28 | 2007-03-29 | 57 | 0d |  |  | AL | 4h | 60,000 |
| 59 | 1.4.6 | Seguimiento Fase II |  | 250h | 2007-02-13 | 2007-03-28 | 41 | 20.35d | 0d | finish no earlier than 2007-03-28 | MR [6%] | 15h | 225,000 |
| 60 | 1.4.7 | Módulos Fase II | milestone | 0d | 2007-03-28 | 2007-03-28 | 59 | 20.19d |  | start no earlier than 2007-02-28 |  |  |  |
| 61 | 1.5 | **FASE III** |  | 19.69d | 2007-03-29 | 2007-04-26 |  | 0d |  |  |  | 295h | 1,895,000 |
| 62 | 1.5.1 | **Levantamiento de Información** |  | 0.5d | 2007-03-29 | 2007-03-29 |  | 0d |  |  |  | 4h | 60,000 |
| 63 | 1.5.1.1 | Sesión de Trabajo única |  | 4h | 2007-03-29 | 2007-03-29 | 53 | 0d |  |  | MR | 4h | 60,000 |
| 64 | 1.5.2 | Documento de Especificación de Requerimientos |  | 1d | 2007-03-29 | 2007-03-30 | 62 | 0d |  |  | MR | 8h | 120,000 |
| 65 | 1.5.3 | Análisis y Diseño |  | 1d | 2007-03-30 | 2007-04-02 | 64 | 0d |  |  | MR | 8h | 120,000 |
| 66 | 1.5.4 | **Módulo de Control y Seguimiento** |  | 16d | 2007-04-02 | 2007-04-25 |  | 1.19d | 0d |  |  | 264h | 1,430,000 |
| 67 | 1.5.4.1 | **Asignación de RRHH y Materiales** |  | 10d | 2007-04-02 | 2007-04-16 |  | 7.19d |  |  |  | 160h | 500,000 |
| 68 | 1.5.4.1.1 | Uso de Materiales |  | 5d | 2007-04-02 | 2007-04-09 | 65 | 7.19d | 0d |  | EC | 40h | 250,000 |
| 69 | 1.5.4.1.2 | Ocupación de Recursos Humanos |  | 5d | 2007-04-09 | 2007-04-16 | 68 | 7.19d |  |  | EC | 40h | 250,000 |
| 70 | 1.5.4.2 | Avance |  | 4d | 2007-04-02 | 2007-04-06 | 65 | 1.19d | 0d |  | DS [50%] | 16h | 100,000 |
| 71 | 1.5.4.3 | Embudo de Ventas |  | 8d | 2007-04-06 | 2007-04-18 | 70 | 1.19d | 0d |  | DS [50%] | 32h | 200,000 |
| 72 | 1.5.4.4 | Pruebas Internas y Ajustes |  | 2d | 2007-04-18 | 2007-04-23 | 71 | 1.19d | 0d |  | MR; EC; DS [50%] | 40h | 390,000 |
| 73 | 1.5.4.5 | Guías de Usuario |  | 1d | 2007-04-23 | 2007-04-24 | 72 | 1.19d | 0d |  | MR | 8h | 120,000 |
| 74 | 1.5.4.6 | Pruebas de Certificación |  | 1d | 2007-04-24 | 2007-04-25 | 73 | 1.19d |  |  | MR | 8h | 120,000 |
| 75 | 1.5.5 | Seguimiento Fase III |  | 17.19d | 2007-04-02 | 2007-04-26 | 65 | 0d |  | finish no earlier than 2007-04-03 | MR [8%] | 11h | 165,000 |
| 76 | 1.5.6 | Módulos Fase III | milestone | 0d | 2007-04-25 | 2007-04-25 | 66 | 1.19d |  | start no earlier than 2007-03-28 |  |  |  |

| ID | WBS | Task | Duration | Start | Finish | Predecessors | Total slack | Constraint | Resources | Work | Cost |
| --- | --- | --- | --- | --- | --- | --- | --- | --- | --- | --- | --- |
| 77 | 1.6 | **Gerencia de Proyecto** | 135.14d | 2006-10-16 | 2007-04-26 |  | 0.35d |  |  | 78h | 1,170,000 |
| 78 | 1.6.1 | Planificación | 0.5d | 2006-11-16 | 2006-11-16 | 11 | 112.85d |  | MR | 4h | 60,000 |
| 79 | 1.6.2 | Control y Seguimiento | 132.14d | 2006-10-16 | 2007-04-26 |  | 0.35d | finish no earlier than 2007-04-26 | MR [7%] | 74h | 1,110,000 |
| 80 | 1.7 | **Cierre** | 0.5d | 2007-04-26 | 2007-04-27 |  | 0d |  |  | 4h | 60,000 |
| 81 | 1.7.1 | Presentación Cierre de Proyecto | 0.25d | 2007-04-26 | 2007-04-27 | 61 | 0d |  | MR | 2h | 30,000 |
| 82 | 1.7.2 | Reunión Cierre de Proyecto | 2h | 2007-04-27 | 2007-04-27 | 81 | 0d |  | MR | 2h | 30,000 |
